Schedule from MS Project, 2020-07-15 to 2022-05-24.
Centralny Ośrodek Informatyki

## Calendars

- Standardowy: Mon-Fri 09:00-13:00, 14:00-18:00; Sat-Sun off.

## Resources

| Resource |
| --- |
| Właściciel biznesowy |
| Urzędnicy |
| Obywatele |
| Analityk biznesowy |
| Kierownik projektu |
| Specjalista ds. dokumentacji przetargowej |
| Pracownik zakładu zamówień publicznych |
| Przewodniczący komitetu sterującego |
| Wykonawca |
| Tester |
| Koordynator IT |
| Release manager |
| Projektant IT |
| Architekt IT |
| Administrator baz danych |
| Inżynier systemowy |
| Administrator sieci |
| Specjalista ds. promocji |

## Schedule

| ID | WBS | Task | Type | Duration | Start | Finish | Predecessors | Total slack | Constraint | Resources | Work |
| --- | --- | --- | --- | --- | --- | --- | --- | --- | --- | --- | --- |
| 1 | 1 | **Projekt wdrożenia platformy internetowej do składania wniosków on-line w urzędzie** |  | 484.95d | 2020-07-15 | 2022-05-24 |  | 0d |  |  | 12134.9h |
| 2 | 1.1 | **Przygotowanie dokumenacji do ogłoszenia zamówienia (zakres projektu: stworzenie i wdrożenie platformy internetowej do składania wniosków on-line)** |  | 64d | 2020-07-15 | 2020-10-12 |  | 0d |  |  | 744h |
| 3 | 1.1.1 | **Analiza biznesowa (przygotowanie wymagań funkcjonalnych i niefunkcjonalnych, w tym wymiarowanie i ustalenie wymagań wydajnościowych)** |  | 15d | 2020-07-15 | 2020-08-04 |  | 0d |  |  | 264h |
| 4 | 1.1.1.1 | **Warsztaty** |  | 15d | 2020-07-15 | 2020-08-04 |  | 0d |  |  | 264h |
| 5 | 1.1.1.1.1 | **I warsztat z przedstawicielami użytkowników końcowych i urzędnikami obsługującymi wnioski** |  | 5d | 2020-07-15 | 2020-07-21 |  | 0d |  |  | 88h |
| 6 | 1.1.1.1.1.1 | I warsztat z przedstawicielami użytkowników końcowych i urzędnikami obsługującymi wnioski |  | 3d | 2020-07-15 | 2020-07-17 |  | 0d | start no earlier than 2020-07-15 | Właściciel biznesowy; Obywatele; Urzędnicy | 72h |
| 7 | 1.1.1.1.1.2 | Utworzenie pierwszej wersji dokumentu analizy biznesowej po warsztatach (v0.1) |  | 2d | 2020-07-20 | 2020-07-21 | 6 | 0d |  | Analityk biznesowy | 16h |
| 8 | 1.1.1.1.2 | **II warsztat z przedstawicielami użytkowników końcowych i urzędnikami obsługującymi wnioski** |  | 5d | 2020-07-22 | 2020-07-28 |  | 0d |  |  | 88h |
| 9 | 1.1.1.1.2.1 | II warsztat z przedstawicielami użytkowników końcowych i urzędnikami obsługującymi wnioski |  | 3d | 2020-07-22 | 2020-07-24 | 7 | 0d |  | Obywatele; Właściciel biznesowy; Urzędnicy | 72h |
| 10 | 1.1.1.1.2.2 | Utworzenie drugiej wersji dokumentu analizy biznesowej po warsztatach (v0.2) |  | 2d | 2020-07-27 | 2020-07-28 | 9 | 0d |  | Analityk biznesowy | 16h |
| 11 | 1.1.1.1.3 | **III warsztat z przedstawicielami użytkowników końcowych i urzędnikami obsługującymi wnioski** |  | 5d | 2020-07-29 | 2020-08-04 |  | 0d |  |  | 88h |
| 12 | 1.1.1.1.3.1 | III warsztat z przedstawicielami użytkowników końcowych i urzędnikami obsługującymi wnioski |  | 3d | 2020-07-29 | 2020-07-31 | 10 | 0d |  | Właściciel biznesowy; Obywatele; Urzędnicy | 72h |
| 13 | 1.1.1.1.3.2 | Utworzenie trzeciej wersji dokumentu analizy biznesowej po warsztatach (v0.3) |  | 2d | 2020-08-03 | 2020-08-04 | 12 | 0d |  | Analityk biznesowy | 16h |
| 14 | 1.1.2 | Weryfikacja wyniku warsztatów z zakresem projektu zawartym w dokumentach SW i WoD |  | 1d | 2020-08-05 | 2020-08-05 | 13 | 0d |  | Analityk biznesowy; Kierownik projektu | 16h |
| 15 | 1.1.3 | Utworzenie finalnej wersji dokumentu analizy biznesowej (v1.0) |  | 2d | 2020-08-06 | 2020-08-07 | 14 | 0d |  | Analityk biznesowy | 16h |
| 16 | 1.1.4 | KM: Akceptacja dokumentu analizy biznesowej przez właściciela biznesowego projeku | milestone | 3d | 2020-08-10 | 2020-08-12 | 15 | 0d |  | Właściciel biznesowy | 24h |
| 17 | 1.1.5 | **Przygotowanie dokumentacji przetargowej** |  | 42d | 2020-08-13 | 2020-10-09 |  | 0d |  |  | 416h |
| 18 | 1.1.5.1 | Przeniesienie wyżej wypracowanych wymagań funkcjonalnych i niefunkcjonalnych na dokument OPZ |  | 10d | 2020-08-13 | 2020-08-26 | 16 | 0d |  | Specjalista ds. dokumentacji przetargowej | 80h |
| 19 | 1.1.5.2 | Przeniesienie wyżej wypracowanych wymagań funkcjonalnych i niefunkcjonalnych na dokument SIWZ |  | 10d | 2020-08-27 | 2020-09-09 | 18 | 0d |  | Specjalista ds. dokumentacji przetargowej | 80h |
| 20 | 1.1.5.3 | **I iteracja uwag do dokumentów OPZ i SIWZ od właściciela biznesowego i zakładu zamówień publicznych** |  | 10d | 2020-09-10 | 2020-09-23 |  | 0d |  |  | 120h |
| 21 | 1.1.5.3.1 | I iteracja uwag do dokumentów OPZ i SIWZ od właściciela biznesowego i zakładu zamówień publicznych |  | 5d | 2020-09-10 | 2020-09-16 | 19 | 0d |  | Pracownik zakładu zamówień publicznych; Właściciel biznesowy | 80h |
| 22 | 1.1.5.3.2 | Naniesienie poprawek na dokumenty OPZ i SIWZ (I iteracja) |  | 5d | 2020-09-17 | 2020-09-23 | 21 | 0d |  | Specjalista ds. dokumentacji przetargowej | 40h |
| 23 | 1.1.5.4 | **II iteracja uwag do dokumentów OPZ i SIWZ od właściciela biznesowego i zakładu zamówień publicznych** |  | 10d | 2020-09-24 | 2020-10-07 |  | 0d |  |  | 120h |
| 24 | 1.1.5.4.1 | II iteracja uwag do dokumentów OPZ i SIWZ od właściciela biznesowego i zakładu zamówień publicznych |  | 5d | 2020-09-24 | 2020-09-30 | 22 | 0d |  | Pracownik zakładu zamówień publicznych; Właściciel biznesowy | 80h |
| 25 | 1.1.5.4.2 | Naniesienie poprawek na dokumenty OPZ i SIWZ (II iteracja) |  | 5d | 2020-10-01 | 2020-10-07 | 24 | 0d |  | Specjalista ds. dokumentacji przetargowej | 40h |
| 26 | 1.1.5.5 | KM: Akceptacja dokumentów OPZ i SIWZ przez właściciela biznesowego | milestone | 2d | 2020-10-08 | 2020-10-09 | 25 | 0d |  | Właściciel biznesowy | 16h |
| 27 | 1.1.6 | Przekazanie dokumentacji przetargowej do zakładu zamówień publicznych |  | 1d | 2020-10-12 | 2020-10-12 | 26 | 0d |  | Kierownik projektu | 8h |

Notes:
- 3: W kolumnie "Nazwy zasobów" powinny znaleźć się konkretne osoby wymienione z imienia i nazwiska (nie powinna zawierać jedynie ról projektowych)

| ID | WBS | Task | Type | Duration | Start | Finish | Predecessors | Total slack | Free slack | Resources | Work |
| --- | --- | --- | --- | --- | --- | --- | --- | --- | --- | --- | --- |
| 28 | 1.2 | **Przeprowadzenie zamówienia (postępowania)** |  | 63d | 2020-10-13 | 2021-01-07 |  | 0d |  |  | 184h |
| 29 | 1.2.1 | Ogłoszenie przetagów na stronie BIP urzędu |  | 2d | 2020-10-13 | 2020-10-14 | 27 | 0d |  | Pracownik zakładu zamówień publicznych | 16h |
| 30 | 1.2.2 | Bufor na ew. odwołania w KIO i zmiany w dokumentacji po zapytaniach od potencjalnych wykonawców |  | 20d | 2020-10-15 | 2020-11-11 | 29 | 0d |  | Kierownik projektu | 160h |
| 31 | 1.2.3 | Wyłonienie wykonawcy |  | 40d | 2020-11-12 | 2021-01-06 | 30 | 0d |  |  |  |
| 32 | 1.2.4 | KM: Podpisanie umowy z wyłonionym wykonawcą | milestone | 1d | 2021-01-07 | 2021-01-07 | 31 | 0d |  | Przewodniczący komitetu sterującego | 8h |
| 33 | 1.3 | **Odbiór dokumentacji dot. przeprowadzenia testów** |  | 48d | 2021-01-08 | 2021-03-16 |  | 68.49d |  |  | 744h |
| 34 | 1.3.1 | **Wykonanie dokumentu planu przeprowadzenia testów** |  | 18d | 2021-01-08 | 2021-02-02 |  | 68.49d |  |  | 296h |
| 35 | 1.3.1.1 | **I iteracja uwag** |  | 8d | 2021-01-08 | 2021-01-19 |  | 68.49d |  |  | 112h |
| 36 | 1.3.1.1.1 | Wykonanie pierwszej wersji dokumentu planu przeprowadzenia testów |  | 5d | 2021-01-08 | 2021-01-14 | 32 | 68.49d | 0d | Wykonawca | 40h |
| 37 | 1.3.1.1.2 | Zapoznanie się i zgłoszenie uwag do dokumentu planu przeprowadzenia testów |  | 3d | 2021-01-15 | 2021-01-19 | 36 | 68.49d | 0d | Tester; Analityk biznesowy; Koordynator IT | 72h |
| 38 | 1.3.1.2 | **II iteracja uwag** |  | 5d | 2021-01-20 | 2021-01-26 |  | 68.49d |  |  | 72h |
| 39 | 1.3.1.2.1 | Wykonanie kolejnej wersji dokumentu planu przeprowadzenia testów |  | 3d | 2021-01-20 | 2021-01-22 | 37 | 68.49d | 0d | Wykonawca | 24h |
| 40 | 1.3.1.2.2 | Zapoznanie się i zgłoszenie ostatecznych uwag do dokumentu planu przeprowadzenia testów |  | 2d | 2021-01-25 | 2021-01-26 | 39 | 68.49d | 0d | Tester; Analityk biznesowy; Koordynator IT | 48h |
| 41 | 1.3.1.3 | Stworzenie finalnej wersji dokumentu planu przeprowadzenia testów |  | 1d | 2021-01-27 | 2021-01-27 | 40 | 68.49d | 0d | Wykonawca | 8h |
| 42 | 1.3.1.4 | Ostateczna weryfikacja dokumentu planu przeprowadzenia testów |  | 3d | 2021-01-28 | 2021-02-01 | 41 | 68.49d | 0d | Tester; Analityk biznesowy; Koordynator IT; Kierownik projektu | 96h |
| 43 | 1.3.1.5 | KM: Formalny odbiór dokumentu planu przeprowadzenia testów | milestone | 1d | 2021-02-02 | 2021-02-02 | 42 | 68.49d | 0d | Właściciel biznesowy | 8h |
| 44 | 1.3.2 | **Wykonanie dokumentu scenariuszy testowych** |  | 30d | 2021-02-03 | 2021-03-16 |  | 68.49d |  |  | 448h |
| 45 | 1.3.2.1 | **Wykonanie scenariuszy testowych do testów jednostkowych / funkcjonalnych** |  | 16d | 2021-02-03 | 2021-02-24 |  | 68.49d |  |  | 184h |
| 46 | 1.3.2.1.1 | **I iteracja** |  | 8d | 2021-02-03 | 2021-02-12 |  | 68.49d |  |  | 80h |
| 47 | 1.3.2.1.1.1 | Wykonanie pierwszej wersji dokumentu scenariuszy testowych do testów jednostkowych |  | 5d | 2021-02-03 | 2021-02-09 | 43 | 68.49d | 0d | Wykonawca | 40h |
| 48 | 1.3.2.1.1.2 | Weryfikacja dokumentu scenariuszy testowych do testów jednostkowych z dokumentem analizy biznesowej (pokrycie testami wszystkich procesów opisanych w dokumencie analizy biznesowej) |  | 1d | 2021-02-10 | 2021-02-10 | 47 | 68.49d | 0d | Analityk biznesowy | 8h |
| 49 | 1.3.2.1.1.3 | Weryfikacja dokumentu scenariuszy testowych do testów jednostkowych |  | 2d | 2021-02-11 | 2021-02-12 | 48 | 68.49d | 0d | Analityk biznesowy; Tester | 32h |
| 50 | 1.3.2.1.2 | **II iteracja** |  | 4d | 2021-02-15 | 2021-02-18 |  | 68.49d |  |  | 40h |
| 51 | 1.3.2.1.2.1 | Wykonanie kolejnej wersji dokumentu scenariuszy testowych do testów jednostkowych |  | 3d | 2021-02-15 | 2021-02-17 | 49 | 68.49d | 0d | Wykonawca | 24h |
| 52 | 1.3.2.1.2.2 | Weryfikacja dokumentu scenariuszy testowych do testów jednostkowych |  | 1d | 2021-02-18 | 2021-02-18 | 51 | 68.49d | 0d | Analityk biznesowy; Tester | 16h |
| 53 | 1.3.2.1.3 | Wykonanie ostatecznej wersji dokumentu scenariuszy testowych do testów jednostkowych |  | 1d | 2021-02-19 | 2021-02-19 | 52 | 68.49d | 0d | Wykonawca | 8h |
| 54 | 1.3.2.1.4 | Weryfikacja ostatecznej wersji dokumentu scenariuszy testowych do testów jednostkowych |  | 2d | 2021-02-22 | 2021-02-23 | 53 | 68.49d | 0d | Analityk biznesowy; Tester; Kierownik projektu | 48h |
| 55 | 1.3.2.1.5 | KM: akceptacja ostatecznej wersji dokumentu scenariuszy testowych do testów jednostkowych / funkcjonalnych | milestone | 1d | 2021-02-24 | 2021-02-24 | 54 | 68.49d |  | Właściciel biznesowy | 8h |

| ID | WBS | Task | Type | Duration | Start | Finish | Predecessors | Total slack | Free slack | Resources | Work |
| --- | --- | --- | --- | --- | --- | --- | --- | --- | --- | --- | --- |
| 56 | 1.3.2.2 | **Wykonanie scenariuszy testowych do testów integracyjnych** |  | 18d | 2021-02-03 | 2021-02-26 |  | 146.62d |  |  | 168h |
| 57 | 1.3.2.2.1 | **I iteracja** |  | 10d | 2021-02-03 | 2021-02-16 |  | 146.62d |  |  | 80h |
| 58 | 1.3.2.2.1.1 | Wykonanie pierwszej wersji dokumentu scenariuszy testowych do testów integracyjnych |  | 5d | 2021-02-03 | 2021-02-09 | 47SS | 146.62d | 0d | Wykonawca | 40h |
| 59 | 1.3.2.2.1.2 | Weryfikacja proponowanego zakresu testów integracyjnych |  | 2d | 2021-02-10 | 2021-02-11 | 58 | 146.62d | 0d | Projektant IT | 16h |
| 60 | 1.3.2.2.1.3 | Zgłoszenie uwag do dokumentu scenariuszy testowych do przeprowadzenia testów integracyjnych |  | 3d | 2021-02-12 | 2021-02-16 | 59 | 146.62d | 0d | Tester | 24h |
| 61 | 1.3.2.2.2 | **II iteracja** |  | 5d | 2021-02-17 | 2021-02-23 |  | 146.62d |  |  | 40h |
| 62 | 1.3.2.2.2.1 | Wykonanie kolejnej wersji dokumentu scenariuszy testowych do testów integracyjnych |  | 3d | 2021-02-17 | 2021-02-19 | 60 | 146.62d | 0d | Wykonawca | 24h |
| 63 | 1.3.2.2.2.2 | Zgłoszenie kolejnych uwag do dokumentu scenariuszy testowych do przeprowadzenia testów integracyjnych |  | 2d | 2021-02-22 | 2021-02-23 | 62 | 146.62d | 0d | Tester | 16h |
| 64 | 1.3.2.2.3 | Wykonanie ostatecznej wersji dokumentu scenariuszy testowych do testów integracyjnych |  | 1d | 2021-02-24 | 2021-02-24 | 63 | 146.62d | 0d | Wykonawca | 8h |
| 65 | 1.3.2.2.4 | Weryfikacja ostatecznej wersji dokumentu scenariuszy testowych do testów integracyjnych |  | 1d | 2021-02-25 | 2021-02-25 | 64 | 146.62d | 0d | Kierownik projektu; Koordynator IT; Projektant IT; Tester | 32h |
| 66 | 1.3.2.2.5 | KM: akceptacja ostatecznej wersji dokumentu scenariuszy testowych do testów integracyjnych | milestone | 1d | 2021-02-26 | 2021-02-26 | 65 | 146.62d | 0d | Właściciel biznesowy | 8h |
| 67 | 1.3.2.3 | **Wykonanie scenariuszy testowych do testów wydajnościowych, bezpieczeństwa / automatycznych wraz z wykonaniem skryptów** |  | 8d | 2021-03-01 | 2021-03-10 |  | 217.37d |  |  | 64h |
| 68 | 1.3.2.3.1 | **I iteracja** |  | 5d | 2021-03-01 | 2021-03-05 |  | 217.37d |  |  | 40h |
| 69 | 1.3.2.3.1.1 | Przygotowanie pierwszej wersji dokumentu scenariuszy testowych do testów wydajnościowych, bezpieczeństwa wraz ze skryptami |  | 3d | 2021-03-01 | 2021-03-03 | 66 | 217.37d | 0d | Wykonawca | 24h |
| 70 | 1.3.2.3.1.2 | Zgłoszenie uwag do pierwszej wersji dokumentu i weryfikacja skryptów |  | 2d | 2021-03-04 | 2021-03-05 | 69 | 217.37d | 0d | Koordynator IT | 16h |
| 71 | 1.3.2.3.2 | **II iteracja** |  | 3d | 2021-03-08 | 2021-03-10 |  | 217.37d |  |  | 24h |
| 72 | 1.3.2.3.2.1 | Przygotowanie kolejnej wersji dokumentu scenariuszy testowych do testów wydajnościowych, bezpieczeństwa wraz ze skryptami |  | 2d | 2021-03-08 | 2021-03-09 | 70 | 217.37d | 0d | Wykonawca | 16h |
| 73 | 1.3.2.3.2.2 | Zgłoszenie uwag do kolejnej wersji dokumentu i ponowna weryfikacja skryptów |  | 1d | 2021-03-10 | 2021-03-10 | 72 | 217.37d | 0d | Koordynator IT | 8h |
| 74 | 1.3.2.4 | Przygotowanie ostatecznej wersji dokumentu scenariuszy testowych do testów wydajnościowych, bezpieczeństwa wraz ze skryptami |  | 1d | 2021-03-11 | 2021-03-11 | 73 | 217.37d | 0d | Wykonawca | 8h |
| 75 | 1.3.2.5 | Weryfikacja ostatecznej wersji dokumentu scenariuszy testowych do testów wydajnościowych, bezpieczeństwa wraz ze skryptami |  | 1d | 2021-03-12 | 2021-03-12 | 74 | 217.37d | 0d | Koordynator IT | 8h |
| 76 | 1.3.2.6 | Przekazanie skryptów do repozytorium gitlab |  | 0.5d | 2021-03-15 | 2021-03-15 | 75 | 217.37d | 0d | Wykonawca | 4h |
| 77 | 1.3.2.7 | Weryfikacja przekazania skryptów do repozytorium gitlab |  | 0.5d | 2021-03-15 | 2021-03-15 | 76 | 217.37d | 0d | Koordynator IT | 4h |
| 78 | 1.3.2.8 | KM: akceptacja scenariuszy testowych do testów wydajnościowych, bezpieczeństwa wraz z odbiorem skryptów | milestone | 1d | 2021-03-16 | 2021-03-16 | 77 | 217.37d |  | Koordynator IT | 8h |
| 79 | 1.4 | **Odbiór dokumentacji technicznej** |  | 154d | 2020-08-13 | 2021-03-16 |  | 86d |  |  | 1312h |
| 80 | 1.4.1 | **Odbiór analizy wykonalności platformy** |  | 20d | 2020-08-13 | 2020-09-09 |  | 86d |  |  | 184h |
| 81 | 1.4.1.1 | **I iteracja** |  | 7d | 2020-08-13 | 2020-08-21 |  | 86d |  |  | 56h |
| 82 | 1.4.1.1.1 | Stworzenie pierwszej wersji dokumentu analizy wykonalności |  | 5d | 2020-08-13 | 2020-08-19 | 16 | 66d | 0d | Projektant IT | 40h |
| 83 | 1.4.1.1.2 | Weryfikacja pierwszej wersji dokumentu analizy wykonalności |  | 2d | 2020-08-20 | 2020-08-21 | 82 | 66d | 0d | Architekt IT | 16h |

| ID | WBS | Task | Type | Duration | Start | Finish | Predecessors | Total slack | Free slack | Resources | Work |
| --- | --- | --- | --- | --- | --- | --- | --- | --- | --- | --- | --- |
| 84 | 1.4.1.2 | **II iteracja** |  | 3d | 2020-08-24 | 2020-08-26 |  | 86d |  |  | 24h |
| 85 | 1.4.1.2.1 | Stworzenie kolejnej wersji dokumentu analizy wykonalności |  | 2d | 2020-08-24 | 2020-08-25 | 83 | 66d | 0d | Projektant IT | 16h |
| 86 | 1.4.1.2.2 | Weryfikacja kolejnej wersji dokumentu analizy wykonalności |  | 1d | 2020-08-26 | 2020-08-26 | 85 | 66d | 0d | Architekt IT | 8h |
| 87 | 1.4.1.3 | **III iteracja** |  | 2d | 2020-08-27 | 2020-08-28 |  | 86d |  |  | 16h |
| 88 | 1.4.1.3.1 | Stworzenie finalnej wersji dokumentu analizy wykonalności |  | 1d | 2020-08-27 | 2020-08-27 | 86 | 66d | 0d | Projektant IT | 8h |
| 89 | 1.4.1.3.2 | Weryfikacja finalnej wersji dokumentu analizy wykonalności |  | 1d | 2020-08-28 | 2020-08-28 | 88 | 66d | 0d | Architekt IT | 8h |
| 90 | 1.4.1.4 | Warsztat wewnętrzny w celu zebrania ostatecznych uwag do dokumentu analizy wykonalności od szerszego grona |  | 1d | 2020-09-07 | 2020-09-07 | 89FS+5d | 66d | 0d | Administrator baz danych; Analityk biznesowy; Inżynier systemowy; Kierownik projektu; Koordynator IT; Projektant IT; Release manager; Tester; Właściciel biznesowy | 72h |
| 91 | 1.4.1.5 | Aktualizacja dokumentu analizy wykonalności |  | 1d | 2020-09-08 | 2020-09-08 | 90 | 66d | 0d | Projektant IT | 8h |
| 92 | 1.4.1.6 | KM: odbiór / ostateczna akceptacja dokumentu analizy wykonalności | milestone | 1d | 2020-09-09 | 2020-09-09 | 91 | 66d |  | Architekt IT | 8h |
| 93 | 1.4.2 | **Odbiór projektu technicznego platformy** |  | 48d | 2021-01-08 | 2021-03-16 |  | 0d |  |  | 1128h |
| 94 | 1.4.2.1 | **Projektowanie prototypu zgodnie z dobrymi praktykami UX** |  | 48d | 2021-01-08 | 2021-03-16 |  | 309.95d |  |  | 768h |
| 95 | 1.4.2.1.1 | **I iteracja (warsztaty z interesariuszami)** |  | 28d | 2021-01-08 | 2021-02-16 |  | 309.95d |  |  | 368h |
| 96 | 1.4.2.1.1.1 | Przygotowanie pierwszej wersji platformy (interaktywne makiety / atrapy ekranów / GUI) |  | 25d | 2021-01-08 | 2021-02-11 | 32 | 309.95d | 0d | Wykonawca | 200h |
| 97 | 1.4.2.1.1.2 | Warsztaty w celu zebrania pierwszych uwag do makiet interaktywych platformy |  | 3d | 2021-02-12 | 2021-02-16 | 96 | 309.95d | 0d | Analityk biznesowy; Kierownik projektu; Obywatele; Tester; Urzędnicy; Właściciel biznesowy; Wykonawca | 168h |
| 98 | 1.4.2.1.2 | **II iteracja (warsztaty z interesariuszami)** |  | 13d | 2021-02-17 | 2021-03-05 |  | 309.95d |  |  | 248h |
| 99 | 1.4.2.1.2.1 | Przygotowanie kolejnej wersji platformy (interaktywne makiety / atrapy ekranów / GUI) |  | 10d | 2021-02-17 | 2021-03-02 | 97 | 309.95d | 0d | Wykonawca | 80h |
| 100 | 1.4.2.1.2.2 | Warsztaty w celu zebrania kolejnych uwag do makiet interaktywych platformy |  | 3d | 2021-03-03 | 2021-03-05 | 99 | 309.95d | 0d | Analityk biznesowy; Kierownik projektu; Obywatele; Tester; Urzędnicy; Właściciel biznesowy; Wykonawca | 168h |
| 101 | 1.4.2.1.3 | **III iteracja (warsztaty z interesariuszami)** |  | 7d | 2021-03-08 | 2021-03-16 |  | 309.95d |  |  | 152h |
| 102 | 1.4.2.1.3.1 | Przygotowanie finalnej wersji platformy (interaktywne makiety / atrapy ekranów / GUI) |  | 5d | 2021-03-08 | 2021-03-12 | 100 | 309.95d | 0d | Wykonawca | 40h |
| 103 | 1.4.2.1.3.2 | Warsztaty w celu zebrania finalnych uwag do makiet interaktywych platformy |  | 2d | 2021-03-15 | 2021-03-16 | 102 | 309.95d |  | Analityk biznesowy; Kierownik projektu; Obywatele; Tester; Urzędnicy; Właściciel biznesowy; Wykonawca | 112h |
| 104 | 1.4.2.2 | **Wytworzenie dokumentu projektu technicznego** |  | 29d | 2021-01-08 | 2021-02-17 |  | 0d |  |  | 240h |
| 105 | 1.4.2.2.1 | **I iteracja** |  | 18d | 2021-01-08 | 2021-02-02 |  | 0d |  |  | 144h |
| 106 | 1.4.2.2.1.1 | Wykonanie pierwszej wersji dokumentu projektu technicznego |  | 15d | 2021-01-08 | 2021-01-28 | 32, 92 | 0d |  | Wykonawca | 120h |
| 107 | 1.4.2.2.1.2 | Weryfikacja dokumentu projektu technicznego |  | 3d | 2021-01-29 | 2021-02-02 | 106 | 0d |  | Projektant IT | 24h |

| ID | WBS | Task | Type | Duration | Start | Finish | Predecessors | Total slack | Free slack | Resources | Work |
| --- | --- | --- | --- | --- | --- | --- | --- | --- | --- | --- | --- |
| 108 | 1.4.2.2.2 | **II iteracja** |  | 7d | 2021-02-03 | 2021-02-11 |  | 0d |  |  | 56h |
| 109 | 1.4.2.2.2.1 | Wykonanie kolejnej wersji dokumentu projektu technicznego |  | 5d | 2021-02-03 | 2021-02-09 | 107 | 0d |  | Wykonawca | 40h |
| 110 | 1.4.2.2.2.2 | Weryfikacja dokumentu projektu technicznego |  | 2d | 2021-02-10 | 2021-02-11 | 109 | 0d |  | Projektant IT | 16h |
| 111 | 1.4.2.2.3 | **III iteracja** |  | 4d | 2021-02-12 | 2021-02-17 |  | 0d |  |  | 40h |
| 112 | 1.4.2.2.3.1 | Wykonanie finalnej wersji dokumentu projektu technicznego |  | 3d | 2021-02-12 | 2021-02-16 | 110 | 0d |  | Wykonawca | 24h |
| 113 | 1.4.2.2.3.2 | Weryfikacja dokumentu projektu technicznego |  | 1d | 2021-02-17 | 2021-02-17 | 112 | 0d |  | Projektant IT; Architekt IT | 16h |
| 114 | 1.4.2.3 | Prezentacja dokumentu projektu technicznego szerszemu gronu |  | 1d | 2021-03-05 | 2021-03-05 | 113FS+11d | 0d |  | Administrator baz danych; Analityk biznesowy; Architekt IT; Inżynier systemowy; Kierownik projektu; Koordynator IT; Projektant IT; Release manager; Tester; Właściciel biznesowy; Wykonawca | 88h |
| 115 | 1.4.2.4 | Ostateczne poprawki dokumentu |  | 2d | 2021-03-08 | 2021-03-09 | 114 | 0d |  | Wykonawca | 16h |
| 116 | 1.4.2.5 | KM: akceptacja ostatecznej wersji dokumentu projektu technicznego | milestone | 1d | 2021-03-10 | 2021-03-10 | 115 | 0d |  | Architekt IT; Projektant IT | 16h |
| 117 | 1.5 | **Przygotowanie środowisk IT w urzędzie** |  | 54.47d | 2021-01-29 | 2021-04-15 |  | 29d |  |  | 299.76h |
| 118 | 1.5.1 | Dostawa sprzętu (serwery i sprzęt sieciowy) |  | 5d | 2021-01-29 | 2021-02-04 | 32FS+15d | 331.95d | 0d | Wykonawca | 40h |
| 119 | 1.5.2 | Konfiguracja sprzętu |  | 5d | 2021-02-05 | 2021-02-11 | 118 | 331.95d | 0d | Wykonawca | 40h |
| 120 | 1.5.3 | KM: formalny odbiór sprzętu w urzędzie | milestone | 1d | 2021-02-12 | 2021-02-12 | 119 | 331.95d |  | Koordynator IT; Kierownik projektu | 16h |
| 121 | 1.5.4 | **Developerskie** |  | 8.49d | 2021-03-11 | 2021-03-23 |  | 0d |  |  | 67.92h |
| 122 | 1.5.4.1 | Konfiguraca maszyn wirtualnych na serwerach |  | 2d | 2021-03-11 | 2021-03-12 | 116 | 0d |  | Inżynier systemowy | 16h |
| 123 | 1.5.4.2 | Instalacja systemów operacyjnych |  | 2d | 2021-03-15 | 2021-03-16 | 122 | 0d |  | Inżynier systemowy | 16h |
| 124 | 1.5.4.3 | Instalacja baz danych |  | 1d | 2021-03-17 | 2021-03-17 | 123 | 0d |  | Administrator baz danych | 8h |
| 125 | 1.5.4.4 | **Konfiguracja środowiska developerskiego** |  | 3.49d | 2021-03-18 | 2021-03-23 |  | 0d |  |  | 27.92h |
| 126 | 1.5.4.4.1 | Otwarcie portów w firewall-ach |  | 1d | 2021-03-18 | 2021-03-18 | 124 | 0d |  | Administrator sieci | 8h |
| 127 | 1.5.4.4.2 | Konfiguracja urządzeń sieciowych |  | 1d | 2021-03-19 | 2021-03-19 | 126 | 0d |  | Administrator sieci | 8h |
| 128 | 1.5.4.4.3 | Rejestracja domeny |  | 0.33d | 2021-03-22 | 2021-03-22 | 127 | 0d |  | Inżynier systemowy | 2.64h |
| 129 | 1.5.4.4.4 | Instalacja certyfikatu HTTPS |  | 0.33d | 2021-03-22 | 2021-03-22 | 128 | 0d |  | Inżynier systemowy | 2.64h |
| 130 | 1.5.4.4.5 | Integracja z MS AD |  | 0.33d | 2021-03-22 | 2021-03-22 | 129 | 0d |  | Inżynier systemowy | 2.64h |
| 131 | 1.5.4.4.6 | Konfiguracja IIS (serwera WWW MS) |  | 0.5d | 2021-03-22 | 2021-03-23 | 130 | 0d |  | Inżynier systemowy | 4h |
| 132 | 1.5.5 | KM: środowisko developerskie w urzędzie utworzone i skonfigurowane | milestone | 0d | 2021-03-23 | 2021-03-23 | 131 | 0d |  |  |  |

| ID | WBS | Task | Type | Duration | Start | Finish | Predecessors | Total slack | Free slack | Resources | Work |
| --- | --- | --- | --- | --- | --- | --- | --- | --- | --- | --- | --- |
| 133 | 1.5.6 | **Testowe / integracyjne** |  | 8.49d | 2021-03-23 | 2021-04-02 |  | 257d |  |  | 67.92h |
| 134 | 1.5.6.1 | Konfiguraca maszyn wirtualnych na serwerach |  | 2d | 2021-03-23 | 2021-03-25 | 132 | 257d | 0d | Inżynier systemowy | 16h |
| 135 | 1.5.6.2 | Instalacja systemów operacyjnych |  | 2d | 2021-03-25 | 2021-03-29 | 134 | 257d | 0d | Inżynier systemowy | 16h |
| 136 | 1.5.6.3 | Instalacja baz danych |  | 1d | 2021-03-29 | 2021-03-30 | 135 | 257d | 0d | Administrator baz danych | 8h |
| 137 | 1.5.6.4 | **Konfiguracja środowiska testowego / integracyjnego** |  | 3.49d | 2021-03-30 | 2021-04-02 |  | 257d |  |  | 27.92h |
| 138 | 1.5.6.4.1 | Otwarcie portów w firewall-ach |  | 1d | 2021-03-30 | 2021-03-31 | 136 | 257d | 0d | Administrator sieci | 8h |
| 139 | 1.5.6.4.2 | Konfiguracja urządzeń sieciowych |  | 1d | 2021-03-31 | 2021-04-01 | 138 | 257d | 0d | Administrator sieci | 8h |
| 140 | 1.5.6.4.3 | Rejestracja domeny |  | 0.33d | 2021-04-01 | 2021-04-01 | 139 | 257d | 0d | Inżynier systemowy | 2.64h |
| 141 | 1.5.6.4.4 | Instalacja certyfikatu HTTPS |  | 0.33d | 2021-04-01 | 2021-04-02 | 140 | 257d | 0d | Inżynier systemowy | 2.64h |
| 142 | 1.5.6.4.5 | Integracja z MS AD |  | 0.33d | 2021-04-02 | 2021-04-02 | 141 | 257d | 0d | Inżynier systemowy | 2.64h |
| 143 | 1.5.6.4.6 | Konfiguracja IIS (serwera WWW MS) |  | 0.5d | 2021-04-02 | 2021-04-02 | 142 | 257d | 0d | Inżynier systemowy | 4h |
| 144 | 1.5.6.5 | KM: środowisko testowe / integracyjne w urzędzie utworzone i skonfigurowane | milestone | 0d | 2021-04-02 | 2021-04-02 | 143 | 257d | 0d |  |  |
| 145 | 1.5.7 | **Produkcyjne** |  | 8.49d | 2021-04-02 | 2021-04-15 |  | 257d |  |  | 67.92h |
| 146 | 1.5.7.1 | Konfiguraca maszyn wirtualnych na serwerach |  | 2d | 2021-04-02 | 2021-04-06 | 144 | 257d | 0d | Inżynier systemowy | 16h |
| 147 | 1.5.7.2 | Instalacja systemów operacyjnych |  | 2d | 2021-04-06 | 2021-04-08 | 146 | 257d | 0d | Inżynier systemowy | 16h |
| 148 | 1.5.7.3 | Instalacja baz danych |  | 1d | 2021-04-08 | 2021-04-09 | 147 | 257d | 0d | Administrator baz danych | 8h |
| 149 | 1.5.7.4 | **Konfiguraca środowiska produkcyjnego** |  | 3.49d | 2021-04-09 | 2021-04-15 |  | 257d |  |  | 27.92h |
| 150 | 1.5.7.4.1 | Otwarcie portów w firewall-ach |  | 1d | 2021-04-09 | 2021-04-12 | 148 | 257d | 0d | Administrator sieci | 8h |
| 151 | 1.5.7.4.2 | Konfiguracja urządzeń sieciowych |  | 1d | 2021-04-12 | 2021-04-13 | 150 | 257d | 0d | Administrator sieci | 8h |
| 152 | 1.5.7.4.3 | Rejestracja domeny |  | 0.33d | 2021-04-13 | 2021-04-14 | 151 | 257d | 0d | Inżynier systemowy | 2.64h |
| 153 | 1.5.7.4.4 | Instalacja certyfikatu HTTPS |  | 0.33d | 2021-04-14 | 2021-04-14 | 152 | 257d | 0d | Inżynier systemowy | 2.64h |
| 154 | 1.5.7.4.5 | Integracja z MS AD |  | 0.33d | 2021-04-14 | 2021-04-14 | 153 | 257d | 0d | Inżynier systemowy | 2.64h |
| 155 | 1.5.7.4.6 | Konfiguracja IIS (serwera WWW MS) |  | 0.5d | 2021-04-14 | 2021-04-15 | 154 | 257d | 0d | Inżynier systemowy | 4h |
| 156 | 1.5.7.5 | KM: środowisko produkcyjne w urzędzie utworzone i skonfigurowane | milestone | 0d | 2021-04-15 | 2021-04-15 | 155 | 257d | 0d |  |  |

| ID | WBS | Task | Duration | Start | Finish | Predecessors | Total slack | Free slack | Resources | Work |
| --- | --- | --- | --- | --- | --- | --- | --- | --- | --- | --- |
| 157 | 1.6 | **Zmiany projektowe (obsługa wniosków o zmianę - bez konieczności procesowania w CPPC)** | 31.48d | 2021-04-15 | 2021-05-28 |  | 257d |  |  | 192.96h |
| 158 | 1.6.1 | **Zaakceptowane przez komitet sterujący** | 18.98d | 2021-04-15 | 2021-05-12 |  | 257d |  |  | 65.12h |
| 159 | 1.6.1.1 | **Podniesienie stosu technologicznego platformy (niwelacja długu technologicznego urzędu)** | 18.98d | 2021-04-15 | 2021-05-12 |  | 257d |  |  | 65.12h |
| 160 | 1.6.1.1.1 | **Podniesienie wersji serwera IIS (serwera WWW MS)** | 18.98d | 2021-04-15 | 2021-05-12 |  | 257d |  |  | 65.12h |
| 161 | 1.6.1.1.1.1 | Analiza wpływu na inne funkjonujące w urzędzie systemy produkcyjne | 2d | 2021-04-15 | 2021-04-19 | 156 | 257d | 0d | Projektant IT | 16h |
| 162 | 1.6.1.1.1.2 | Analiza możliwości wykonania ew. przyszłych integracji z innymi istniejącymi systemami produkcyjnymi w urzedzie | 1d | 2021-04-19 | 2021-04-20 | 161 | 257d | 0d | Projektant IT | 8h |
| 163 | 1.6.1.1.1.3 | Analiza zgodności licencyjnej i ew. wzrostu kosztów | 1d | 2021-04-20 | 2021-04-21 | 162 | 257d | 0d | Kierownik projektu | 8h |
| 164 | 1.6.1.1.1.4 | Ostateczna weryfikacja techniczna wpływu zmiany na zakres projektu i ew. przyszłą możliwość rozwoju czy też integracji wewnętrznych | 1d | 2021-04-21 | 2021-04-22 | 163 | 257d | 0d | Architekt IT | 8h |
| 165 | 1.6.1.1.1.5 | Uzyskano wewnętrzną pozytywną rekomendację realizacji zmiany | 0.33d | 2021-04-22 | 2021-04-22 | 164 | 257d | 0d | Architekt IT; Projektant IT; Kierownik projektu | 7.92h |
| 166 | 1.6.1.1.1.6 | Akceptacja zmiany na komitecie sterującym | 0.33d | 2021-04-29 | 2021-04-30 | 165FS+5d | 257d | 0d | Przewodniczący komitetu sterującego | 2.64h |
| 167 | 1.6.1.1.1.7 | **Realizacja zaakceptowanej zmiany technicznej** | 8.32d | 2021-04-30 | 2021-05-12 |  | 257d |  |  | 14.56h |
| 168 | 1.6.1.1.1.7.1 | Ustalenie okienka serwisowego (ustalenie bezpiecznego terminu realizacji aktualizacji) | 0.33d | 2021-04-30 | 2021-04-30 | 166 | 257d | 0d | Kierownik projektu | 2.64h |
| 169 | 1.6.1.1.1.7.2 | Aktualizacja na środowisku developerskim (godziny nocne) | 0.33d | 2021-05-11 | 2021-05-11 | 168FS+7d | 257d | 0d | Inżynier systemowy | 2.64h |
| 170 | 1.6.1.1.1.7.3 | Aktualizacja na środowisku testowym / integracyjnym (godziny nocne) | 0.33d | 2021-05-11 | 2021-05-12 | 169 | 269.5d | 0d | Inżynier systemowy | 2.64h |
| 171 | 1.6.1.1.1.7.4 | Aktualizacja na środowisku produkcyjnym (godziny nocne) | 0.33d | 2021-05-12 | 2021-05-12 | 170 | 269.5d |  | Inżynier systemowy | 2.64h |
| 172 | 1.6.1.1.1.7.5 | Smoke testy (szybkie testy funkcjonalne po wdrożeniu aktualizacji, godziny nocne) | 0.5d | 2021-05-11 | 2021-05-12 | 169 | 257d | 0d | Tester | 4h |
| 173 | 1.6.2 | **Odrzucone przez komitet sterujący** | 12.66d | 2021-05-12 | 2021-05-28 |  | 257d |  |  | 127.84h |
| 174 | 1.6.2.1 | **Podniesienie stosu technologicznego platformy (niwelacja długu technologicznego urzędu)** | 12.66d | 2021-05-12 | 2021-05-28 |  | 257d |  |  | 127.84h |
| 175 | 1.6.2.1.1 | **Podniesienie wersji silnika baz danych** | 9.33d | 2021-05-12 | 2021-05-25 |  | 257d |  |  | 55.92h |
| 176 | 1.6.2.1.1.1 | Analiza wpływu na inne funkjonujące w urzędzie systemy produkcyjne (negatywna) | 2d | 2021-05-12 | 2021-05-14 | 172 | 257d | 0d | Projektant IT | 16h |
| 177 | 1.6.2.1.1.2 | Analiza możliwości wykonania ew. przyszłych integracji z innymi istniejącymi systemami produkcyjnymi w urzedzie | 1d | 2021-05-14 | 2021-05-17 | 176 | 257d | 0d | Projektant IT | 8h |
| 178 | 1.6.2.1.1.3 | Analiza zgodności licencyjnej i ew. wzrostu kosztów (negatywna) | 1d | 2021-05-17 | 2021-05-18 | 177 | 257d | 0d | Kierownik projektu | 8h |
| 179 | 1.6.2.1.1.4 | Ostateczna weryfikacja techniczna wpływu zmiany na zakres projektu i ew. przyszłą możliwość rozwoju czy też integracji wewnętrznych (wynik negatywny) | 1d | 2021-05-18 | 2021-05-19 | 178 | 257d | 0d | Architekt IT | 8h |
| 180 | 1.6.2.1.1.5 | Uzyskano wewnętrzną negatywną rekomendację realizacji zmiany | 0.33d | 2021-05-19 | 2021-05-19 | 179 | 257d | 0d | Architekt IT; Projektant IT; Kierownik projektu | 7.92h |
| 181 | 1.6.2.1.1.6 | Odrzucenie zmiany na komitecie sterującym | 1d | 2021-05-24 | 2021-05-25 | 180FS+3d | 260.33d |  | Przewodniczący komitetu sterującego | 8h |

Notes:
- 160: W toku prac projektowych okazało się że potrzebne są funkonalności z wyższej wersji serwera IIS

| ID | WBS | Task | Type | Duration | Start | Finish | Predecessors | Total slack | Free slack | Resources | Work |
| --- | --- | --- | --- | --- | --- | --- | --- | --- | --- | --- | --- |
| 182 | 1.6.2.1.2 | **Zmiana ekranu logowania do platformy** |  | 7.33d | 2021-05-19 | 2021-05-28 |  | 257d |  |  | 71.92h |
| 183 | 1.6.2.1.2.1 | Analiza zmiany funkcjonalnej przez analityka biznesowego (wstępna pozytywna) |  | 1d | 2021-05-19 | 2021-05-20 | 180 | 257d | 0d | Analityk biznesowy | 8h |
| 184 | 1.6.2.1.2.2 | Analiza zmiany funkcjonalnej przez Projektanta IT (negatywna - konflikt technologiczny z zaplanowaną do wdrożenia technologią SSO) |  | 2d | 2021-05-20 | 2021-05-24 | 183 | 257d | 0d | Projektant IT | 16h |
| 185 | 1.6.2.1.2.3 | Wycena ewentualnej zmiany funkcjonalnej u wykonawcy (negatywna - zbyt drogo i za długo) |  | 3d | 2021-05-19 | 2021-05-24 | 183SS | 258d | 1d | Kierownik projektu | 24h |
| 186 | 1.6.2.1.2.4 | Analiza wpływu na pozostałe funkcjonalności wytwarzanej platformy i na ew. możliwość przyszłych integracji (wynik negatywny) |  | 1d | 2021-05-24 | 2021-05-25 | 184 | 257d | 0d | Architekt IT; Projektant IT | 16h |
| 187 | 1.6.2.1.2.5 | Uzyskano wewnętrzną negatywną rekomendację realizacji zmiany |  | 0.33d | 2021-05-25 | 2021-05-25 | 186, 185 | 257d | 0d | Architekt IT; Kierownik projektu; Projektant IT | 7.92h |
| 188 | 1.6.2.1.2.6 | Odrzucenie zmiany na komitecie sterującym |  | 1d | 2021-05-27 | 2021-05-28 | 187FS+2d | 257d |  |  |  |
| 189 | 1.7 | **Development wykonawcy platformy - prace inicjujące** |  | 30d | 2021-03-23 | 2021-05-04 |  | 0d |  |  | 240h |
| 190 | 1.7.1 | Development / wytworzenie pierwszej wersji platformy na środowisku developerskim w urzędzie |  | 30d | 2021-03-23 | 2021-05-04 | 132 | 0d |  | Wykonawca | 240h |
| 191 | 1.8 | **Przeprowadzenie testów oprogramowania oraz dalszy development** |  | 227.46d | 2021-05-04 | 2022-03-17 |  | 0d |  |  | 5622.24h |
| 192 | 1.8.1 | **Instalacja platformy na środowisku testowym / integracyjnym** |  | 20d | 2021-05-04 | 2021-06-01 |  | 0d |  |  | 248h |
| 193 | 1.8.1.1 | Przygotowanie paczek instalacyjnych wraz z instrukcjami instalacji |  | 3d | 2021-05-04 | 2021-05-07 | 190 | 0d |  | Wykonawca | 24h |
| 194 | 1.8.1.2 | Przekazanie paczek instalacyjnych wraz z kodem żródłowym i instrukcjami instalacji do repozytorium (gitlab) |  | 2d | 2021-05-07 | 2021-05-11 | 193 | 0d |  | Wykonawca | 16h |
| 195 | 1.8.1.3 | **Zgłaszanie uwag i poprawki materiału wdrożeniowego** |  | 8d | 2021-05-11 | 2021-05-21 |  | 0d |  |  | 144h |
| 196 | 1.8.1.3.1 | **I iteracja** |  | 5d | 2021-05-11 | 2021-05-18 |  | 0d |  |  | 88h |
| 197 | 1.8.1.3.1.1 | **Weryfikacja zgodności paczek instalacyjnych z wewnętrznymi standardami / procedurami IT w urzędzie** |  | 5d | 2021-05-11 | 2021-05-18 |  | 0d |  |  | 88h |
| 198 | 1.8.1.3.1.1.1 | Zgłoszenie uwag |  | 3d | 2021-05-11 | 2021-05-14 | 194 | 0d |  | Administrator baz danych; Inżynier systemowy; Koordynator IT | 72h |
| 199 | 1.8.1.3.1.1.2 | Poprawa materiału wdrożeniowego i instrukcji instalacyjnych |  | 2d | 2021-05-14 | 2021-05-18 | 198 | 0d |  | Wykonawca | 16h |
| 200 | 1.8.1.3.2 | **II iteracja** |  | 3d | 2021-05-18 | 2021-05-21 |  | 0d |  |  | 56h |
| 201 | 1.8.1.3.2.1 | **Weryfikacja zgodności paczek instalacyjnych z wewnętrznymi standardami / procedurami IT w urzędzie** |  | 3d | 2021-05-18 | 2021-05-21 |  | 0d |  |  | 56h |
| 202 | 1.8.1.3.2.1.1 | Zgłoszenie uwag |  | 2d | 2021-05-18 | 2021-05-20 | 199 | 0d |  | Administrator baz danych; Inżynier systemowy; Koordynator IT | 48h |
| 203 | 1.8.1.3.2.1.2 | Poprawa materiału wdrożeniowego i instrukcji instalacyjnych |  | 1d | 2021-05-20 | 2021-05-21 | 202 | 0d |  | Wykonawca | 8h |
| 204 | 1.8.1.4 | **Instalacja paczek w urzędzie (środowisko testowe / integracyjne)** |  | 7d | 2021-05-21 | 2021-06-01 |  | 0d |  |  | 64h |
| 205 | 1.8.1.4.1 | **I podejście** |  | 4d | 2021-05-21 | 2021-05-27 |  | 0d |  |  | 32h |
| 206 | 1.8.1.4.1.1 | Instalacja paczek bazodanowych |  | 1d | 2021-05-21 | 2021-05-24 | 203 | 0d |  | Administrator baz danych | 8h |
| 207 | 1.8.1.4.1.2 | Instalacja paczek aplikacyjnych |  | 1d | 2021-05-24 | 2021-05-25 | 206 | 0d |  | Inżynier systemowy | 8h |
| 208 | 1.8.1.4.1.3 | Zgłoszenie błędów | milestone | 0d | 2021-05-25 | 2021-05-25 | 207 | 0d |  | Administrator baz danych; Inżynier systemowy |  |
| 209 | 1.8.1.4.1.4 | Poprawa błędów |  | 2d | 2021-05-25 | 2021-05-27 | 208 | 0d |  | Wykonawca | 16h |

| ID | WBS | Task | Type | Duration | Start | Finish | Predecessors | Total slack | Resources | Work |
| --- | --- | --- | --- | --- | --- | --- | --- | --- | --- | --- |
| 210 | 1.8.1.4.2 | **II podejście** |  | 3d | 2021-05-27 | 2021-06-01 |  | 0d |  | 32h |
| 211 | 1.8.1.4.2.1 | Instalacja paczek bazodanowych |  | 0.5d | 2021-05-27 | 2021-05-27 | 209 | 0d | Administrator baz danych | 4h |
| 212 | 1.8.1.4.2.2 | Instalacja paczek aplikacyjnych |  | 0.5d | 2021-05-27 | 2021-05-28 | 211 | 0d | Inżynier systemowy | 4h |
| 213 | 1.8.1.4.2.3 | Zgłoszenie błędów | milestone | 0d | 2021-05-28 | 2021-05-28 | 212 | 0d | Administrator baz danych; Inżynier systemowy |  |
| 214 | 1.8.1.4.2.4 | Poprawa błędów |  | 1d | 2021-05-28 | 2021-05-31 | 213 | 0d | Wykonawca | 8h |
| 215 | 1.8.1.4.2.5 | Instalacja poprawionych paczek instalacjnych na środowisku testowym / integracyjnym |  | 1d | 2021-05-31 | 2021-06-01 | 214 | 0d | Administrator baz danych; Inżynier systemowy | 16h |
| 216 | 1.8.1.5 | KM: paczki instalacyjne budujące platformę zainstalowane z powodzeniem na środowisku testowym / integracyjnym | milestone | 0d | 2021-06-01 | 2021-06-01 | 215 | 0d |  |  |
| 217 | 1.8.2 | **Wykonanie testów funkcjonalnych / jednostkowych** |  | 80.13d | 2021-06-01 | 2021-09-21 |  | 0d |  | 2635.44h |
| 218 | 1.8.2.1 | **I iteracja (etap) testowania** |  | 41.3d | 2021-06-01 | 2021-07-28 |  | 0d |  | 1160h |
| 219 | 1.8.2.1.1 | Wykonanie testów funkjonalnych / jednostkowych na postawie wcześniej odebranych scenariuszy testowych |  | 10d | 2021-06-01 | 2021-06-15 | 216, 55 | 0d | Obywatele; Tester; Urzędnicy | 240h |
| 220 | 1.8.2.1.2 | Równoległe zgłaszanie błędów w aplikacji Jira |  | 10d | 2021-06-01 | 2021-06-15 | 219SS | 245.46d | Obywatele; Tester; Urzędnicy | 240h |
| 221 | 1.8.2.1.3 | Wsparcie administratora baz danych |  | 30.3d | 2021-06-01 | 2021-07-13 | 219SS | 225.16d | Administrator baz danych [33%] | 80h |
| 222 | 1.8.2.1.4 | Wsparcie inżyniera systemowego |  | 30.3d | 2021-06-01 | 2021-07-13 | 219SS | 225.16d | Inżynier systemowy [33%] | 80h |
| 223 | 1.8.2.1.5 | Wsparcie koordynatora IT |  | 30.3d | 2021-06-01 | 2021-07-13 | 219SS | 225.16d | Koordynator IT [33%] | 80h |
| 224 | 1.8.2.1.6 | Wsparcie analityka biznesowego |  | 30.3d | 2021-06-01 | 2021-07-13 | 219SS | 225.16d | Analityk biznesowy [33%] | 80h |
| 225 | 1.8.2.1.7 | Wsparcie projektanta IT |  | 30.3d | 2021-06-01 | 2021-07-13 | 219SS | 225.16d | Projektant IT [33%] | 80h |
| 226 | 1.8.2.1.8 | Koordynacja testów |  | 30.3d | 2021-06-01 | 2021-07-13 | 219SS | 0d | Kierownik projektu [33%] | 80h |
| 227 | 1.8.2.1.9 | **Poprawki błędów i wgranie na środowisko poprawionego materiału wdrożeniowego** |  | 11d | 2021-07-13 | 2021-07-28 |  | 0d |  | 200h |
| 228 | 1.8.2.1.9.1 | Odtworzenie błędów na środowisku testowym / inegracyjnym |  | 5d | 2021-07-13 | 2021-07-20 | 226 | 0d | Wykonawca | 40h |
| 229 | 1.8.2.1.9.2 | Wykonanie poprawek na środowisku developerskim |  | 5d | 2021-07-13 | 2021-07-20 | 228SS | 0d | Wykonawca | 40h |
| 230 | 1.8.2.1.9.3 | Wykonanie testów poprawek na środowisku developerskim |  | 5d | 2021-07-13 | 2021-07-20 | 229SS | 0d | Wykonawca | 40h |
| 231 | 1.8.2.1.9.4 | Przygotowanie paczek instalacyjnych z poprawkami na środowisko testowe |  | 3d | 2021-07-20 | 2021-07-23 | 230 | 0d | Wykonawca | 24h |
| 232 | 1.8.2.1.9.5 | Instalacja paczek z poprawkami na środowisko testowe |  | 2d | 2021-07-23 | 2021-07-27 | 231 | 0d | Administrator baz danych; Inżynier systemowy; Koordynator IT | 48h |
| 233 | 1.8.2.1.9.6 | Wstępna weryfikacja zainstalowanych poprawek na środowisku testowym |  | 1d | 2021-07-27 | 2021-07-28 | 232 | 0d | Wykonawca | 8h |

| ID | WBS | Task | Duration | Start | Finish | Predecessors | Total slack | Free slack | Resources | Work |
| --- | --- | --- | --- | --- | --- | --- | --- | --- | --- | --- |
| 234 | 1.8.2.2 | **II iteracja (etap) testowania** | 28.5d | 2021-07-28 | 2021-09-07 |  | 0d |  |  | 1081.6h |
| 235 | 1.8.2.2.1 | Wykonanie testów funkjonalnych / jednostkowych na postawie wcześniej odebranych scenariuszy testowych | 15d | 2021-07-28 | 2021-08-18 | 233 | 0d |  | Obywatele; Tester; Urzędnicy | 360h |
| 236 | 1.8.2.2.2 | Równoległe zgłaszanie błędów w aplikacji Jira | 15d | 2021-07-28 | 2021-08-18 | 235SS | 0d |  | Obywatele; Tester; Urzędnicy | 360h |
| 237 | 1.8.2.2.3 | Wsparcie administratora baz danych | 15d | 2021-07-28 | 2021-08-18 | 236SS | 199.16d | 0d | Administrator baz danych [33%] | 39.6h |
| 238 | 1.8.2.2.4 | Wsparcie inżyniera systemowego | 15d | 2021-07-28 | 2021-08-18 | 237SS | 199.16d | 0d | Inżynier systemowy [33%] | 39.6h |
| 239 | 1.8.2.2.5 | Wsparcie koordynatora IT | 15d | 2021-07-28 | 2021-08-18 | 238SS | 199.16d | 0d | Koordynator IT [33%] | 39.6h |
| 240 | 1.8.2.2.6 | Wsparcie analityka biznesowego | 15d | 2021-07-28 | 2021-08-18 | 239SS | 199.16d | 0d | Analityk biznesowy [33%] | 39.6h |
| 241 | 1.8.2.2.7 | Wsparcie projektanta IT | 15d | 2021-07-28 | 2021-08-18 | 240SS | 199.16d | 0d | Projektant IT [33%] | 39.6h |
| 242 | 1.8.2.2.8 | Koordynacja testów | 15d | 2021-07-28 | 2021-08-18 | 241SS | 199.16d |  | Kierownik projektu [33%] | 39.6h |
| 243 | 1.8.2.2.9 | **Poprawki błędów i wgranie na środowisko poprawionego materiału wdrożeniowego** | 13.5d | 2021-08-18 | 2021-09-07 |  | 0d |  |  | 124h |
| 244 | 1.8.2.2.9.1 | Odtworzenie błędów na środowisku testowym / inegracyjnym | 5d | 2021-08-18 | 2021-08-25 | 236 | 0d |  | Wykonawca | 40h |
| 245 | 1.8.2.2.9.2 | Wykonanie poprawek na środowisku developerskim | 3d | 2021-08-25 | 2021-08-30 | 244 | 0d |  | Wykonawca | 24h |
| 246 | 1.8.2.2.9.3 | Wykonanie testów poprawek na środowisku developerskim | 2d | 2021-08-30 | 2021-09-01 | 245 | 0d |  | Wykonawca | 16h |
| 247 | 1.8.2.2.9.4 | Przygotowanie paczek instalacyjnych z poprawkami na środowisko testowe | 2d | 2021-09-01 | 2021-09-03 | 246 | 0d |  | Wykonawca | 16h |
| 248 | 1.8.2.2.9.5 | Instalacja paczek z poprawkami na środowisko testowe | 1d | 2021-09-03 | 2021-09-06 | 247 | 0d |  | Administrator baz danych; Inżynier systemowy; Koordynator IT | 24h |
| 249 | 1.8.2.2.9.6 | Wstępna weryfikacja zainstalowanych poprawek na środowisku testowym | 0.5d | 2021-09-06 | 2021-09-07 | 248 | 0d |  | Wykonawca | 4h |
| 250 | 1.8.2.3 | **III iteracja (etap) testowania** | 10.33d | 2021-09-07 | 2021-09-21 |  | 0d |  |  | 393.84h |
| 251 | 1.8.2.3.1 | Wykonanie testów funkjonalnych / jednostkowych na postawie wcześniej odebranych scenariuszy testowych | 5d | 2021-09-07 | 2021-09-14 | 249 | 0d |  | Obywatele; Tester; Urzędnicy | 120h |
| 252 | 1.8.2.3.2 | Równoległe zgłaszanie błędów w aplikacji Jira | 5d | 2021-09-07 | 2021-09-14 | 251SS | 0d |  | Obywatele; Tester; Urzędnicy | 120h |
| 253 | 1.8.2.3.3 | Wsparcie administratora baz danych | 5d | 2021-09-07 | 2021-09-14 | 252SS | 180.66d | 0d | Administrator baz danych [33%] | 13.2h |
| 254 | 1.8.2.3.4 | Wsparcie inżyniera systemowego | 5d | 2021-09-07 | 2021-09-14 | 253SS | 180.66d | 0d | Inżynier systemowy [33%] | 13.2h |
| 255 | 1.8.2.3.5 | Wsparcie koordynatora IT | 5d | 2021-09-07 | 2021-09-14 | 254SS | 180.66d | 0d | Koordynator IT [33%] | 13.2h |
| 256 | 1.8.2.3.6 | Wsparcie analityka biznesowego | 5d | 2021-09-07 | 2021-09-14 | 255SS | 180.66d | 0d | Analityk biznesowy [33%] | 13.2h |
| 257 | 1.8.2.3.7 | Wsparcie projektanta IT | 5d | 2021-09-07 | 2021-09-14 | 256SS | 180.66d | 0d | Projektant IT [33%] | 13.2h |
| 258 | 1.8.2.3.8 | Koordynacja testów | 5d | 2021-09-07 | 2021-09-14 | 257SS | 180.66d |  | Kierownik projektu [33%] | 13.2h |

| ID | WBS | Task | Type | Duration | Start | Finish | Predecessors | Total slack | Free slack | Resources | Work |
| --- | --- | --- | --- | --- | --- | --- | --- | --- | --- | --- | --- |
| 259 | 1.8.2.3.9 | **Poprawki błędów i wgranie na środowisko poprawionego materiału wdrożeniowego** |  | 5.33d | 2021-09-14 | 2021-09-21 |  | 0d |  |  | 74.64h |
| 260 | 1.8.2.3.9.1 | Odtworzenie błędów na środowisku testowym / inegracyjnym |  | 2d | 2021-09-14 | 2021-09-16 | 252 | 0d |  | Wykonawca | 16h |
| 261 | 1.8.2.3.9.2 | Wykonanie poprawek na środowisku developerskim |  | 1d | 2021-09-14 | 2021-09-15 | 260SS | 0d |  | Wykonawca | 8h |
| 262 | 1.8.2.3.9.3 | Wykonanie testów poprawek na środowisku developerskim |  | 1d | 2021-09-15 | 2021-09-16 | 261 | 0d |  | Wykonawca | 8h |
| 263 | 1.8.2.3.9.4 | Przygotowanie paczek instalacyjnych z poprawkami na środowisko testowe |  | 1d | 2021-09-16 | 2021-09-17 | 262 | 0d |  | Wykonawca | 8h |
| 264 | 1.8.2.3.9.5 | Instalacja paczek z poprawkami na środowisko testowe |  | 1d | 2021-09-17 | 2021-09-20 | 263 | 0d |  | Administrator baz danych; Inżynier systemowy; Koordynator IT | 24h |
| 265 | 1.8.2.3.9.6 | Wstępna weryfikacja zainstalowanych poprawek na środowisku testowym |  | 0.33d | 2021-09-20 | 2021-09-20 | 264 | 0d |  | Wykonawca | 2.64h |
| 266 | 1.8.2.3.9.7 | Weryfikacja ostatecznych poprawek przez testera z urzędu |  | 1d | 2021-09-20 | 2021-09-21 | 265 | 0d |  | Tester | 8h |
| 267 | 1.8.3 | KM: zakończenie testów jednostkowych / funkcjonalnych | milestone | 0d | 2021-09-21 | 2021-09-21 | 266 | 118.08d | 67d |  |  |
| 268 | 1.8.4 | **Wykonanie testów integracyjnych** |  | 67d | 2021-09-21 | 2021-12-23 |  | 0d |  |  | 1475.2h |
| 269 | 1.8.4.1 | **I iteracja** |  | 40d | 2021-09-21 | 2021-11-16 |  | 0d |  |  | 1004.8h |
| 270 | 1.8.4.1.1 | Wykonanie testów integracyjnych na podstawie wcześniej odebranych scenariuszy testowych do testów integracyjnych |  | 20d | 2021-09-21 | 2021-10-19 | 266, 66 | 0d |  | Tester | 160h |
| 271 | 1.8.4.1.2 | Równoległe zgłaszanie błędów w aplikacji Jira |  | 20d | 2021-09-21 | 2021-10-19 | 270SS | 0d |  | Tester | 160h |
| 272 | 1.8.4.1.3 | Wsparcie administratora baz danych |  | 20d | 2021-09-21 | 2021-10-19 | 271SS | 155.33d | 0d | Administrator baz danych [33%] | 52.8h |
| 273 | 1.8.4.1.4 | Wsparcie inżyniera systemowego |  | 20d | 2021-09-21 | 2021-10-19 | 272SS | 155.33d | 0d | Inżynier systemowy [33%] | 52.8h |
| 274 | 1.8.4.1.5 | Wsparcie koordynatora IT |  | 20d | 2021-09-21 | 2021-10-19 | 273SS | 155.33d | 0d | Koordynator IT [33%] | 52.8h |
| 275 | 1.8.4.1.6 | Wsparcie analityka biznesowego |  | 20d | 2021-09-21 | 2021-10-19 | 274SS | 155.33d | 0d | Analityk biznesowy [33%] | 52.8h |
| 276 | 1.8.4.1.7 | Wsparcie projektanta IT |  | 20d | 2021-09-21 | 2021-10-19 | 275SS | 155.33d | 0d | Projektant IT [33%] | 52.8h |
| 277 | 1.8.4.1.8 | Koordynacja testów |  | 20d | 2021-09-21 | 2021-10-19 | 276SS | 155.33d |  | Kierownik projektu [33%] | 52.8h |
| 278 | 1.8.4.1.9 | **Poprawki błędów i wgranie na środowisko poprawionego materiału wdrożeniowego** |  | 20d | 2021-10-19 | 2021-11-16 |  | 0d |  |  | 368h |
| 279 | 1.8.4.1.9.1 | Odtworzenie błędów na środowisku testowym / inegracyjnym |  | 10d | 2021-10-19 | 2021-11-02 | 271 | 0d |  | Wykonawca | 80h |
| 280 | 1.8.4.1.9.2 | Wykonanie poprawek na środowisku developerskim |  | 10d | 2021-10-19 | 2021-11-02 | 279SS | 0d |  | Wykonawca | 80h |
| 281 | 1.8.4.1.9.3 | Wykonanie testów poprawek na środowisku developerskim |  | 10d | 2021-10-19 | 2021-11-02 | 280SS | 0d |  | Wykonawca | 80h |
| 282 | 1.8.4.1.9.4 | Przygotowanie paczek instalacyjnych z poprawkami na środowisko testowe |  | 5d | 2021-11-02 | 2021-11-09 | 281 | 0d |  | Wykonawca | 40h |
| 283 | 1.8.4.1.9.5 | Instalacja paczek z poprawkami na środowisko testowe |  | 3d | 2021-11-09 | 2021-11-12 | 282 | 0d |  | Administrator baz danych; Inżynier systemowy; Koordynator IT | 72h |
| 284 | 1.8.4.1.9.6 | Wstępna weryfikacja zainstalowanych poprawek na środowisku testowym |  | 2d | 2021-11-12 | 2021-11-16 | 283 | 0d |  | Wykonawca | 16h |

| ID | WBS | Task | Type | Duration | Start | Finish | Predecessors | Total slack | Free slack | Resources | Work |
| --- | --- | --- | --- | --- | --- | --- | --- | --- | --- | --- | --- |
| 285 | 1.8.4.2 | **II iteracja** |  | 27d | 2021-11-16 | 2021-12-23 |  | 0d |  |  | 470.4h |
| 286 | 1.8.4.2.1 | Wykonanie testów integracyjnych na podstawie wcześniej odebranych scenariuszy testowych do testów integracyjnych |  | 10d | 2021-11-16 | 2021-11-30 | 284 | 0d |  | Tester | 80h |
| 287 | 1.8.4.2.2 | Równoległe zgłaszanie błędów w aplikacji Jira |  | 10d | 2021-11-16 | 2021-11-30 | 286SS | 0d |  | Tester | 80h |
| 288 | 1.8.4.2.3 | Wsparcie administratora baz danych |  | 10d | 2021-11-16 | 2021-11-30 | 287SS | 125.33d | 0d | Administrator baz danych [33%] | 26.4h |
| 289 | 1.8.4.2.4 | Wsparcie inżyniera systemowego |  | 10d | 2021-11-16 | 2021-11-30 | 288SS | 125.33d | 0d | Inżynier systemowy [33%] | 26.4h |
| 290 | 1.8.4.2.5 | Wsparcie koordynatora IT |  | 10d | 2021-11-16 | 2021-11-30 | 289SS | 125.33d | 0d | Koordynator IT [33%] | 26.4h |
| 291 | 1.8.4.2.6 | Wsparcie analityka biznesowego |  | 10d | 2021-11-16 | 2021-11-30 | 290SS | 125.33d | 0d | Analityk biznesowy [33%] | 26.4h |
| 292 | 1.8.4.2.7 | Wsparcie projektanta IT |  | 10d | 2021-11-16 | 2021-11-30 | 291SS | 125.33d | 0d | Projektant IT [33%] | 26.4h |
| 293 | 1.8.4.2.8 | Koordynacja testów |  | 10d | 2021-11-16 | 2021-11-30 | 292SS | 125.33d |  | Kierownik projektu [33%] | 26.4h |
| 294 | 1.8.4.2.9 | **Poprawki błędów i wgranie na środowisko poprawionego materiału wdrożeniowego** |  | 17d | 2021-11-30 | 2021-12-23 |  | 0d |  |  | 152h |
| 295 | 1.8.4.2.9.1 | Odtworzenie błędów na środowisku testowym / inegracyjnym |  | 5d | 2021-11-30 | 2021-12-07 | 287 | 0d |  | Wykonawca | 40h |
| 296 | 1.8.4.2.9.2 | Wykonanie poprawek na środowisku developerskim |  | 3d | 2021-12-07 | 2021-12-10 | 295 | 0d |  | Wykonawca | 24h |
| 297 | 1.8.4.2.9.3 | Wykonanie testów poprawek na środowisku developerskim |  | 3d | 2021-12-10 | 2021-12-15 | 296 | 0d |  | Wykonawca | 24h |
| 298 | 1.8.4.2.9.4 | Przygotowanie paczek instalacyjnych z poprawkami na środowisko testowe |  | 2d | 2021-12-15 | 2021-12-17 | 297 | 0d |  | Wykonawca | 16h |
| 299 | 1.8.4.2.9.5 | Instalacja paczek z poprawkami na środowisko testowe |  | 1d | 2021-12-17 | 2021-12-20 | 298 | 0d |  | Administrator baz danych; Inżynier systemowy; Koordynator IT | 24h |
| 300 | 1.8.4.2.9.6 | Wstępna weryfikacja zainstalowanych poprawek na środowisku testowym |  | 1d | 2021-12-20 | 2021-12-21 | 299 | 0d |  | Wykonawca | 8h |
| 301 | 1.8.4.2.9.7 | Weryfikacja ostatecznych poprawek przez testera z urzędu |  | 2d | 2021-12-21 | 2021-12-23 | 300 | 0d |  | Tester | 16h |
| 302 | 1.8.5 | KM: zakończenie testów integracyjnych | milestone | 0d | 2021-12-23 | 2021-12-23 | 301 | 0d |  |  |  |
| 303 | 1.8.6 | **Wykonanie testów wydajnościowych i stabilności (środowisko produkcyjne)** |  | 36.08d | 2021-12-23 | 2022-02-11 |  | 0d |  |  | 593.12h |
| 304 | 1.8.6.1 | Analiza techniczna czy można wykonać testy wydajnościowe od razu na środowisku produkcyjnym |  | 0.5d | 2021-12-23 | 2021-12-24 | 302 | 0d |  | Projektant IT; Architekt IT | 8h |
| 305 | 1.8.6.2 | Pozytywna rekomendacja |  | 0.25d | 2021-12-24 | 2021-12-24 | 304 | 0d |  | Architekt IT | 2h |
| 306 | 1.8.6.3 | **Instalacja platformy na środowisku produkcyjnym** |  | 15d | 2021-12-24 | 2022-01-14 |  | 0d |  |  | 232h |
| 307 | 1.8.6.3.1 | Przygotowanie materiału wdrożeniowego (paczek instalacyjnych i instrukcji) |  | 3d | 2021-12-24 | 2021-12-29 | 305 | 0d |  | Wykonawca | 24h |
| 308 | 1.8.6.3.2 | Przgląd materiału wdrożeniowego i zgłoszenie uwag (zgodność z procedurami IT w urzędzie, merytoryczny przegląd kodu / skryptów instalacyjnych) |  | 2d | 2021-12-29 | 2021-12-31 | 307 | 0d |  | Administrator baz danych; Inżynier systemowy; Koordynator IT | 48h |
| 309 | 1.8.6.3.3 | Poprawa zgłoszonych błędów |  | 1d | 2021-12-31 | 2022-01-03 | 308 | 0d |  | Wykonawca | 8h |
| 310 | 1.8.6.3.4 | Ostateczna weryfikacja poprawek paczek instalacyjnych i instrukcji |  | 1d | 2022-01-03 | 2022-01-04 | 309 | 0d |  | Administrator baz danych; Inżynier systemowy; Koordynator IT | 24h |
| 311 | 1.8.6.3.5 | Wypracowanie terminu wdrożenia i planu wdrożenia na produkcję (w tym zasad komunikacji podczas wdrożenia i kolejności instalowania paczek instalacyjnych) |  | 1d | 2022-01-07 | 2022-01-10 | 310FS+3d | 0d |  | Administrator baz danych; Administrator sieci; Architekt IT; Inżynier systemowy; Kierownik projektu; Koordynator IT; Projektant IT; Release manager; Właściciel biznesowy | 72h |

Notes:
- 303: Testy wydajnościowe można było przeprowadzić na środowisku produkcyjnym ponieważ były to zupełnie nowe komponenty w środowisku IT urzędu (testy nie miały negatynego wpływu na inne produkcyjnie działające systemy w urzędzie)

| ID | WBS | Task | Type | Duration | Start | Finish | Predecessors | Total slack | Resources | Work |
| --- | --- | --- | --- | --- | --- | --- | --- | --- | --- | --- |
| 312 | 1.8.6.3.6 | **Instalacja** |  | 1d | 2022-01-13 | 2022-01-14 |  | 0d |  | 56h |
| 313 | 1.8.6.3.6.1 | Instalacja paczek dot. serwera IIS |  | 1d | 2022-01-13 | 2022-01-14 | 311FS+3d | 0d | Inżynier systemowy | 8h |
| 314 | 1.8.6.3.6.2 | Instalacja paczek dot. baz danych |  | 1d | 2022-01-13 | 2022-01-14 | 313SS | 0d | Administrator baz danych | 8h |
| 315 | 1.8.6.3.6.3 | Konfiguracja sieciowa |  | 1d | 2022-01-13 | 2022-01-14 | 314SS | 0d | Administrator sieci | 8h |
| 316 | 1.8.6.3.6.4 | Koordynacja instalacji przez koordynatora IT |  | 1d | 2022-01-13 | 2022-01-14 | 315SS | 0d | Koordynator IT | 8h |
| 317 | 1.8.6.3.6.5 | Koordynacja komunikacji podczas wdrożenia na produkcję |  | 1d | 2022-01-13 | 2022-01-14 | 316SS | 0d | Kierownik projektu | 8h |
| 318 | 1.8.6.3.6.6 | Zdalne wsparcie podczas instalacji platformy na produkcji |  | 1d | 2022-01-13 | 2022-01-14 | 317SS | 0d | Wykonawca | 8h |
| 319 | 1.8.6.3.6.7 | Wykonanie smoke testów (szybkie testy funkcjonalne potwierdzające wstępnie działanie rozwiązania) |  | 1d | 2022-01-13 | 2022-01-14 | 318SS | 0d | Tester | 8h |
| 320 | 1.8.6.3.7 | KM: Platforma zainstalowana na środowisku produkcyjnym | milestone | 0d | 2022-01-14 | 2022-01-14 | 319 | 0d |  |  |
| 321 | 1.8.6.4 | **Wykonanie testów** |  | 20.33d | 2022-01-14 | 2022-02-11 |  | 0d |  | 351.12h |
| 322 | 1.8.6.4.1 | **I iteracja** |  | 9d | 2022-01-14 | 2022-01-27 |  | 0d |  | 140.8h |
| 323 | 1.8.6.4.1.1 | Wykonanie testów zgodnie z planem testów, scenariuszami testów wydajnościowych i obciążeniowych |  | 5d | 2022-01-14 | 2022-01-21 | 78, 43, 320 | 0d | Wykonawca | 40h |
| 324 | 1.8.6.4.1.2 | Wsparcie podczas wykonywania testów wydajnościowych |  | 5d | 2022-01-14 | 2022-01-21 | 323SS | 0d | Administrator baz danych [33%]; Administrator sieci [33%]; Inżynier systemowy [33%]; Koordynator IT [33%] | 52.8h |
| 325 | 1.8.6.4.1.3 | Poprawa błędów wykrytych podczas I iteracji testów wydajnościowych (wykrycie "wąskich gardeł" i optymalizacja rozwiązania) |  | 2d | 2022-01-21 | 2022-01-25 | 324 | 0d | Wykonawca | 16h |
| 326 | 1.8.6.4.1.4 | Przygotowanie poprawionych paczek instalacyjnych |  | 1d | 2022-01-25 | 2022-01-26 | 325 | 0d | Wykonawca | 8h |
| 327 | 1.8.6.4.1.5 | Instalacja paczek z poprawkami |  | 1d | 2022-01-26 | 2022-01-27 | 326 | 0d | Administrator baz danych; Inżynier systemowy; Koordynator IT | 24h |
| 328 | 1.8.6.4.2 | **II iteracja** |  | 11.33d | 2022-01-27 | 2022-02-11 |  | 0d |  | 210.32h |
| 329 | 1.8.6.4.2.1 | Wykonanie testów zgodnie z planem testów, scenariuszami testów wydajnościowych i obciążeniowych |  | 3d | 2022-01-27 | 2022-02-01 | 327 | 0d | Wykonawca | 24h |
| 330 | 1.8.6.4.2.2 | Wsparcie podczas wykonywania testów wydajnościowych |  | 3d | 2022-01-27 | 2022-02-01 | 329SS | 0d | Administrator baz danych [33%]; Administrator sieci [33%]; Inżynier systemowy [33%]; Koordynator IT [33%] | 31.68h |
| 331 | 1.8.6.4.2.3 | Poprawa błędów wykrytych podczas II iteracji testów wydajnościowych (wykrycie "wąskich gardeł" i optymalizacja rozwiązania) |  | 1d | 2022-02-01 | 2022-02-02 | 330 | 0d | Wykonawca | 8h |
| 332 | 1.8.6.4.2.4 | Przygotowanie poprawionych paczek instalacyjnych |  | 1d | 2022-02-02 | 2022-02-03 | 331 | 0d | Wykonawca | 8h |
| 333 | 1.8.6.4.2.5 | Instalacja paczek z poprawkami |  | 1d | 2022-02-03 | 2022-02-04 | 332 | 0d | Administrator baz danych; Inżynier systemowy; Koordynator IT | 24h |
| 334 | 1.8.6.4.2.6 | Ostateczna weryfikacja spełnienia wymagań wydajnościowych |  | 1d | 2022-02-04 | 2022-02-07 | 333 | 0d | Wykonawca | 8h |
| 335 | 1.8.6.4.2.7 | Przygotowanie raportu z testów wydajnościowych (spełnienie wymagań wydajnościowych zapisanych w analizie biznesowej oraz w projekcie technicznym, opis skryptów i narzędzi użytych do testów, opis środowiska produkcyjnego i wersji komponentów, opis danych) |  | 3d | 2022-02-07 | 2022-02-10 | 334 | 0d | Wykonawca | 24h |
| 336 | 1.8.6.4.2.8 | Omówienie raportu przez wykonawcę w urzędzie |  | 1d | 2022-02-10 | 2022-02-11 | 335 | 0d | Administrator baz danych; Analityk biznesowy; Architekt IT; Inżynier systemowy; Kierownik projektu; Koordynator IT; Projektant IT; Tester; Właściciel biznesowy; Wykonawca | 80h |
| 337 | 1.8.6.4.2.9 | Akceptacja raportu z testów wydajnościowych przez koordynatora IT |  | 0.33d | 2022-02-11 | 2022-02-11 | 336 | 0d | Koordynator IT | 2.64h |
| 338 | 1.8.6.5 | KM: testy wydajnościowe zakończone | milestone | 0d | 2022-02-11 | 2022-02-11 | 337 | 0d |  |  |

| ID | WBS | Task | Type | Duration | Start | Finish | Predecessors | Total slack | Free slack | Resources | Work |
| --- | --- | --- | --- | --- | --- | --- | --- | --- | --- | --- | --- |
| 339 | 1.8.7 | **Wykonanie audytu / testów bezpieczeństwa (środowisko produkcyjne)** |  | 24.25d | 2022-02-11 | 2022-03-17 |  | 0d |  |  | 366.48h |
| 340 | 1.8.7.1 | **I iteracja** |  | 11d | 2022-02-11 | 2022-02-28 |  | 0d |  |  | 156.8h |
| 341 | 1.8.7.1.1 | Wykonanie testów zgodnie z planem testów, scenariuszami testów bezpieczeństwa |  | 5d | 2022-02-11 | 2022-02-18 | 338 | 0d |  | Wykonawca | 40h |
| 342 | 1.8.7.1.2 | Wsparcie podczas wykonywania testów bezpieczeństwa |  | 5d | 2022-02-11 | 2022-02-18 | 341SS | 0d |  | Administrator baz danych [33%]; Administrator sieci [33%]; Inżynier systemowy [33%]; Koordynator IT [33%] | 52.8h |
| 343 | 1.8.7.1.3 | Poprawa błędów wykrytych podczas I iteracji testów bezpieczeństwa (wykrycie podatności czy potencjalnych luk bezpieczeństwa i optymalizacja rozwiązania) |  | 3d | 2022-02-18 | 2022-02-23 | 342 | 0d |  | Wykonawca | 24h |
| 344 | 1.8.7.1.4 | Przygotowanie poprawionych paczek instalacyjnych |  | 2d | 2022-02-23 | 2022-02-25 | 343 | 0d |  | Wykonawca | 16h |
| 345 | 1.8.7.1.5 | Instalacja paczek z poprawkami |  | 1d | 2022-02-25 | 2022-02-28 | 344 | 0d |  | Administrator baz danych; Inżynier systemowy; Koordynator IT | 24h |
| 346 | 1.8.7.2 | **II iteracja** |  | 13.25d | 2022-02-28 | 2022-03-17 |  | 0d |  |  | 209.68h |
| 347 | 1.8.7.2.1 | Wykonanie testów zgodnie z planem testów, scenariuszami testów bezpieczeństwa |  | 3d | 2022-02-28 | 2022-03-03 | 345 | 0d |  | Wykonawca | 24h |
| 348 | 1.8.7.2.2 | Wsparcie podczas wykonywania testów bezpieceństwa |  | 3d | 2022-02-28 | 2022-03-03 | 347SS | 0d |  | Administrator baz danych [33%]; Administrator sieci [33%]; Inżynier systemowy [33%]; Koordynator IT [33%] | 31.68h |
| 349 | 1.8.7.2.3 | Poprawa błędów wykrytych podczas II iteracji testów bezpieczeństwa (wykrycie podatności czy potencjalnych luk bezpieczeństwa i optymalizacja rozwiązania) |  | 2d | 2022-03-03 | 2022-03-07 | 348 | 0d |  | Wykonawca | 16h |
| 350 | 1.8.7.2.4 | Przygotowanie poprawionych paczek instalacyjnych |  | 1d | 2022-03-07 | 2022-03-08 | 349 | 0d |  | Wykonawca | 8h |
| 351 | 1.8.7.2.5 | Instalacja paczek z poprawkami |  | 1d | 2022-03-08 | 2022-03-09 | 350 | 0d |  | Administrator baz danych; Inżynier systemowy; Koordynator IT | 24h |
| 352 | 1.8.7.2.6 | Ostateczna weryfikacja spełnienia wymagań dot. bezpieczeństwa |  | 1d | 2022-03-09 | 2022-03-10 | 351 | 0d |  | Wykonawca | 8h |
| 353 | 1.8.7.2.7 | Przygotowanie raportu z testów bezpieczeństwa (spełnienie wymagań dot. bezpieczeństwa w tym OWASP top 10, lista wykrytych podatności z prorytetami wraz z informacją o sposobie "załatania dziur", opis metodyki, użytych narzędzi i specyfikacja środowiska) |  | 2d | 2022-03-10 | 2022-03-14 | 352 | 0d |  | Wykonawca | 16h |
| 354 | 1.8.7.2.8 | Omówienie raportu przez wykonawcę w urzędzie |  | 1d | 2022-03-16 | 2022-03-17 | 353FS+2d | 0d |  | Administrator baz danych; Analityk biznesowy; Architekt IT; Inżynier systemowy; Kierownik projektu; Koordynator IT; Projektant IT; Tester; Właściciel biznesowy; Wykonawca | 80h |
| 355 | 1.8.7.2.9 | Akceptacja raportu z testów bezpieczeństwa przez koordynatora IT |  | 0.25d | 2022-03-17 | 2022-03-17 | 354 | 0d |  | Koordynator IT | 2h |
| 356 | 1.8.7.3 | KM: testy bezpieczeństwa zakończone | milestone | 0d | 2022-03-17 | 2022-03-17 | 355 | 0d |  |  |  |
| 357 | 1.8.8 | **Wykonanie audytu zgodności z WCAG 2.1 (środowisko testowe / integracyjne i produkcyjne)** |  | 15d | 2021-12-23 | 2022-01-13 |  | 40.33d |  |  | 304h |
| 358 | 1.8.8.1 | Wykonanie audytu z WCAG 2.1 |  | 10d | 2021-12-23 | 2022-01-06 | 267, 302 | 40.33d | 0d | Wykonawca; Obywatele; Urzędnicy | 240h |
| 359 | 1.8.8.2 | Przygotowanie raportu z audytu WCAG 2.1 |  | 3d | 2022-01-06 | 2022-01-11 | 358 | 40.33d | 0d | Wykonawca | 24h |
| 360 | 1.8.8.3 | Prezentacja raportu w urzędzie |  | 1d | 2022-01-11 | 2022-01-12 | 359 | 40.33d | 0d | Kierownik projektu; Koordynator IT; Właściciel biznesowy; Wykonawca | 32h |
| 361 | 1.8.8.4 | Akceptacja raportu z audytu WCAG 2.1 |  | 1d | 2022-01-12 | 2022-01-13 | 360 | 40.33d | 0d | Właściciel biznesowy | 8h |
| 362 | 1.8.8.5 | KM: audyt dot. spełnienia wymagań WCAG 2.1 zakończony wynikiem pozytywnym | milestone | 0d | 2022-01-13 | 2022-01-13 | 361 | 40.33d | 0d |  |  |
| 363 | 1.9 | KM: UZYSKANIE GOTOWOŚCI DO URUCHOMIENIA PRODUKCYJNEGO PLATFORMY | milestone | 0d | 2022-03-17 | 2022-03-17 | 362, 356, 338, 302, 267 | 48d |  |  |  |

| ID | WBS | Task | Duration | Start | Finish | Predecessors | Total slack | Free slack | Resources | Work |
| --- | --- | --- | --- | --- | --- | --- | --- | --- | --- | --- |
| 364 | 1.10 | **Odbiór pozostałej dokumentacji projektowej** | 72.33d | 2021-12-23 | 2022-04-04 |  | 36d |  |  | 640h |
| 365 | 1.10.1 | **Instrukcja obsługi platformy dla obywatela / interesariusza** | 15d | 2021-12-23 | 2022-01-13 |  | 78.33d |  |  | 120h |
| 366 | 1.10.1.1 | **I iteracja** | 8d | 2021-12-23 | 2022-01-04 |  | 78.33d |  |  | 64h |
| 367 | 1.10.1.1.1 | Wykonanie pierwszej wersji instrukcji | 5d | 2021-12-23 | 2021-12-30 | 302 | 78.33d | 0d | Wykonawca | 40h |
| 368 | 1.10.1.1.2 | Zgłoszenie uwag do instrukcji | 3d | 2021-12-30 | 2022-01-04 | 367 | 78.33d | 0d | Obywatele | 24h |
| 369 | 1.10.1.2 | **II iteracja** | 5d | 2022-01-04 | 2022-01-11 |  | 78.33d |  |  | 40h |
| 370 | 1.10.1.2.1 | Wykonanie kolejnej wersji instrukcji | 3d | 2022-01-04 | 2022-01-07 | 368 | 78.33d | 0d | Wykonawca | 24h |
| 371 | 1.10.1.2.2 | Zgłoszenie uwag do instrukcji | 2d | 2022-01-07 | 2022-01-11 | 370 | 78.33d | 0d | Obywatele | 16h |
| 372 | 1.10.1.3 | Przygotowanie ostatecznej wersji instrukcji | 1d | 2022-01-11 | 2022-01-12 | 371 | 78.33d | 0d | Wykonawca | 8h |
| 373 | 1.10.1.4 | Akceptacja instrukcji | 1d | 2022-01-12 | 2022-01-13 | 372 | 78.33d | 0d | Właściciel biznesowy | 8h |
| 374 | 1.10.2 | **Instrukcja obsługi platformy dla urzędnika** | 15d | 2022-01-13 | 2022-02-03 |  | 78.33d |  |  | 120h |
| 375 | 1.10.2.1 | **I iteracja** | 8d | 2022-01-13 | 2022-01-25 |  | 78.33d |  |  | 64h |
| 376 | 1.10.2.1.1 | Wykonanie pierwszej wersji instrukcji | 5d | 2022-01-13 | 2022-01-20 | 373 | 78.33d | 0d | Wykonawca | 40h |
| 377 | 1.10.2.1.2 | Zgłoszenie uwag do instrukcji | 3d | 2022-01-20 | 2022-01-25 | 376 | 78.33d | 0d | Urzędnicy | 24h |
| 378 | 1.10.2.2 | **II iteracja** | 5d | 2022-01-25 | 2022-02-01 |  | 78.33d |  |  | 40h |
| 379 | 1.10.2.2.1 | Wykonanie kolejnej wersji instrukcji | 3d | 2022-01-25 | 2022-01-28 | 377 | 78.33d | 0d | Wykonawca | 24h |
| 380 | 1.10.2.2.2 | Zgłoszenie uwag do instrukcji | 2d | 2022-01-28 | 2022-02-01 | 379 | 78.33d | 0d | Urzędnicy | 16h |
| 381 | 1.10.2.3 | Przygotowanie ostatecznej wersji instrukcji | 1d | 2022-02-01 | 2022-02-02 | 380 | 78.33d | 0d | Wykonawca | 8h |
| 382 | 1.10.2.4 | Akceptacja instrukcji | 1d | 2022-02-02 | 2022-02-03 | 381 | 78.33d |  | Właściciel biznesowy | 8h |
| 383 | 1.10.3 | **Instrukcja dla administratorów platformy** | 10d | 2022-03-17 | 2022-03-31 |  | 38d |  |  | 152h |
| 384 | 1.10.3.1 | **I iteracja** | 5d | 2022-03-17 | 2022-03-24 |  | 38d |  |  | 88h |
| 385 | 1.10.3.1.1 | Wykonanie pierwszej wersji instrukcji | 3d | 2022-03-17 | 2022-03-22 | 356 | 38d | 0d | Wykonawca | 24h |
| 386 | 1.10.3.1.2 | Zgłoszenie uwag do instrukcji | 2d | 2022-03-22 | 2022-03-24 | 385 | 38d | 0d | Administrator baz danych; Administrator sieci; Inżynier systemowy; Koordynator IT | 64h |
| 387 | 1.10.3.2 | **II iteracja** | 3d | 2022-03-24 | 2022-03-29 |  | 38d |  |  | 48h |
| 388 | 1.10.3.2.1 | Wykonanie kolejnej wersji instrukcji | 2d | 2022-03-24 | 2022-03-28 | 386 | 38d | 0d | Wykonawca | 16h |
| 389 | 1.10.3.2.2 | Zgłoszenie uwag do instrukcji | 1d | 2022-03-28 | 2022-03-29 | 388 | 38d | 0d | Administrator baz danych; Administrator sieci; Inżynier systemowy; Koordynator IT | 32h |
| 390 | 1.10.3.3 | Przygotowanie ostatecznej wersji instrukcji | 1d | 2022-03-29 | 2022-03-30 | 389 | 38d | 0d | Wykonawca | 8h |
| 391 | 1.10.3.4 | Akceptacja instrukcji | 1d | 2022-03-30 | 2022-03-31 | 390 | 38d |  | Koordynator IT | 8h |

| ID | WBS | Task | Type | Duration | Start | Finish | Predecessors | Total slack | Free slack | Resources | Work |
| --- | --- | --- | --- | --- | --- | --- | --- | --- | --- | --- | --- |
| 392 | 1.10.4 | **Dokumentacja powykonawcza platformy** |  | 12d | 2022-03-17 | 2022-04-04 |  | 36d |  |  | 120h |
| 393 | 1.10.4.1 | **Aktualizacja dokumentu analizy wykonalności** |  | 5d | 2022-03-17 | 2022-03-24 |  | 36d |  |  | 48h |
| 394 | 1.10.4.1.1 | Aktualizacja dokumentu analizy wykonalności |  | 3d | 2022-03-17 | 2022-03-22 | 356 | 36d | 0d | Wykonawca | 24h |
| 395 | 1.10.4.1.2 | Weryfikacja aktualizacji dokumentu analizy wykonalności |  | 1d | 2022-03-22 | 2022-03-23 | 394 | 36d | 0d | Architekt IT; Projektant IT | 16h |
| 396 | 1.10.4.1.3 | Akceptacja aktualizacji dokumentu analizy wykonalności |  | 1d | 2022-03-23 | 2022-03-24 | 395 | 36d | 0d | Architekt IT | 8h |
| 397 | 1.10.4.2 | **Aktualizacja dokumentu projektu technicznego** |  | 7d | 2022-03-24 | 2022-04-04 |  | 36d |  |  | 72h |
| 398 | 1.10.4.2.1 | Aktualizacja dokumentu projektu technicznego |  | 4d | 2022-03-24 | 2022-03-30 | 396 | 36d | 0d | Wykonawca | 32h |
| 399 | 1.10.4.2.2 | Weryfikacja aktualizacji dokumentu projektu technicznego |  | 2d | 2022-03-30 | 2022-04-01 | 398 | 36d | 0d | Architekt IT; Projektant IT | 32h |
| 400 | 1.10.4.2.3 | Akceptacja aktualizacji dokumentu projektu technicznego |  | 1d | 2022-04-01 | 2022-04-04 | 399 | 36d |  | Architekt IT | 8h |
| 401 | 1.10.5 | **Materiały szkoleniowe dla urzędników i administratorów** |  | 53.33d | 2022-01-13 | 2022-03-29 |  | 0d |  |  | 128h |
| 402 | 1.10.5.1 | **Administratorzy** |  | 8d | 2022-03-17 | 2022-03-29 |  | 0d |  |  | 64h |
| 403 | 1.10.5.1.1 | Wykonanie materiałów szkoleniowych dla administratorów |  | 5d | 2022-03-17 | 2022-03-24 | 356 | 0d |  | Wykonawca | 40h |
| 404 | 1.10.5.1.2 | Przygotowanie środowiska testowego do przeprowadzenia szkoleń (założenie testowych użytkowników, przygotowanie danych szkoleniowych) |  | 3d | 2022-03-24 | 2022-03-29 | 403 | 0d |  | Wykonawca | 24h |
| 405 | 1.10.5.2 | **Urzędnicy** |  | 8d | 2022-01-13 | 2022-01-25 |  | 40.33d |  |  | 64h |
| 406 | 1.10.5.2.1 | Wykonanie materiałów szkoleniowych dla urzędników |  | 5d | 2022-01-13 | 2022-01-20 | 362 | 40.33d | 0d | Wykonawca | 40h |
| 407 | 1.10.5.2.2 | Przygotowanie środowiska testowego do przeprowadzenia szkoleń (założenie testowych użytkowników, przygotowanie danych szkoleniowych) |  | 3d | 2022-01-20 | 2022-01-25 | 406 | 40.33d | 0d | Wykonawca | 24h |
| 408 | 1.11 | **Szkolenia** |  | 58.33d | 2022-01-13 | 2022-04-05 |  | 35d |  |  | 930h |
| 409 | 1.11.1 | **Administratorzy** |  | 13d | 2022-03-17 | 2022-04-05 |  | 8d |  |  | 290h |
| 410 | 1.11.1.1 | Przygotowanie listy obecności, przygotowanie sprzętu komputerowego i Sali szkoleniowej, w tym catering |  | 5d | 2022-03-17 | 2022-03-24 | 403SS | 43d |  | Kierownik projektu | 40h |
| 411 | 1.11.1.2 | Przeprowadzenie szkoleń dla administratorów platformy w urzędzie |  | 5d | 2022-03-29 | 2022-04-05 | 404 | 0d |  | Administrator baz danych; Administrator sieci; Inżynier systemowy; Koordynator IT; Wykonawca | 200h |
| 412 | 1.11.1.3 | Wsparcie techniczne podczas szkolenia |  | 5d | 2022-03-29 | 2022-04-05 | 411SS | 35d |  | Administrator baz danych [25%]; Administrator sieci [25%]; Inżynier systemowy [25%]; Koordynator IT [25%]; Wykonawca [25%] | 50h |
| 413 | 1.11.2 | **Urzędnicy** |  | 18d | 2022-01-13 | 2022-02-08 |  | 48.33d |  |  | 640h |
| 414 | 1.11.2.1 | Przygotowanie listy obecności, przygotowanie sprzętu komputerowego i sali szkoleniowej, w tym catering |  | 10d | 2022-01-13 | 2022-01-27 | 406SS | 83.33d |  | Kierownik projektu | 80h |
| 415 | 1.11.2.2 | Przeprowadzenie szkoleń dla wybranej grupy urzędników |  | 10d | 2022-01-25 | 2022-02-08 | 407 | 40.33d | 0d | Urzędnicy; Wykonawca | 160h |
| 416 | 1.11.2.3 | Wsparcie techniczne podczas szkolenia |  | 10d | 2022-01-25 | 2022-02-08 | 415SS | 75.33d |  | Administrator baz danych; Administrator sieci; Inżynier systemowy; Koordynator IT; Wykonawca | 400h |
| 417 | 1.12 | KM: zakończenie szkoleń w projekcie | milestone | 0d | 2022-04-05 | 2022-04-05 | 411, 415 | 0d |  |  |  |

| ID | WBS | Task | Type | Duration | Start | Finish | Predecessors | Total slack | Free slack | Resources | Work |
| --- | --- | --- | --- | --- | --- | --- | --- | --- | --- | --- | --- |
| 418 | 1.13 | **Uruchomienie produkcyjne platformy** |  | 18d | 2022-03-31 | 2022-04-26 |  | 3d |  |  | 1008h |
| 419 | 1.13.1 | Wypracowanie planu uruchomienia produkcyjnego platformy |  | 1d | 2022-03-31 | 2022-04-01 | 417FS-3d | 35d | 0d | Administrator baz danych; Administrator sieci; Architekt IT; Inżynier systemowy; Kierownik projektu; Koordynator IT; Projektant IT; Release manager; Właściciel biznesowy; Wykonawca | 80h |
| 420 | 1.13.2 | Akceptacja planu uruchomienia platformy na produkcji |  | 1d | 2022-04-04 | 2022-04-05 | 419FS+1d | 35d |  | Przewodniczący komitetu sterującego | 8h |
| 421 | 1.13.3 | **Pilot** |  | 5d | 2022-04-05 | 2022-04-12 |  | 0d |  |  | 280h |
| 422 | 1.13.3.1 | Udostępnienie produkcyjne platformy wybranej wcześniej grupie obywateli i urzędników |  | 5d | 2022-04-05 | 2022-04-12 | 417 | 0d |  | Obywatele; Urzędnicy | 80h |
| 423 | 1.13.3.2 | Wsparcie techniczne wykonawcy |  | 5d | 2022-04-05 | 2022-04-12 | 422SS | 30d | 0d | Wykonawca | 40h |
| 424 | 1.13.3.3 | Wewnętrzne wsparcie techniczne w urzędzie |  | 5d | 2022-04-05 | 2022-04-12 | 423SS | 30d |  | Administrator baz danych; Administrator sieci; Inżynier systemowy; Koordynator IT | 160h |
| 425 | 1.13.4 | **Roll-out** |  | 10d | 2022-04-12 | 2022-04-26 |  | 0d |  |  | 640h |
| 426 | 1.13.4.1 | Udostępnienie produkcyjne platformy wszystkim obywatelom i urzędnikom |  | 10d | 2022-04-12 | 2022-04-26 | 422 | 0d |  | Obywatele; Urzędnicy | 160h |
| 427 | 1.13.4.2 | Uruchomienie działań promujących rozwiązanie jakim jest platforma |  | 10d | 2022-04-12 | 2022-04-26 | 426SS | 20d |  | Specjalista ds. promocji | 80h |
| 428 | 1.13.4.3 | Wsparcie techniczne wykonawcy |  | 10d | 2022-04-12 | 2022-04-26 | 426SS | 20d | 0d | Wykonawca | 80h |
| 429 | 1.13.4.4 | Wewnętrzne wsparcie techniczne w urzędzie |  | 10d | 2022-04-12 | 2022-04-26 | 428SS | 20d |  | Administrator baz danych; Administrator sieci; Inżynier systemowy; Koordynator IT | 320h |
| 430 | 1.14 | KM: Platforma uruchomiona produkcyjnie | milestone | 0d | 2022-04-26 | 2022-04-26 | 426 | 20d |  |  |  |
| 431 | 1.15 | **Odbiór oprogramowania platformy** |  | 20d | 2022-04-26 | 2022-05-24 |  | 0d |  |  | 24h |
| 432 | 1.15.1 | Przekazanie ostatecznej wersji kodu źródłowego platformy do repozytorium urzędu (narzędzie gitlab) |  | 1d | 2022-04-26 | 2022-04-27 | 426 | 17d | 0d | Wykonawca | 8h |
| 433 | 1.15.2 | Weryfikacja przekazanych kodów |  | 1d | 2022-04-27 | 2022-04-28 | 432 | 17d | 0d | Projektant IT | 8h |
| 434 | 1.15.3 | Formalny odbiór głównego produktu projektu (platformy) |  | 1d | 2022-04-28 | 2022-04-29 | 433 | 17d |  | Przewodniczący komitetu sterującego | 8h |
| 435 | 1.15.4 | **Stabilizacja po wdrożeniu na produkcję** |  | 20d | 2022-04-26 | 2022-05-24 |  | 0d |  |  |  |
| 436 | 1.15.4.1 | Zdalne wsparcie wykonawcy |  | 20d | 2022-04-26 | 2022-05-24 | 426 | 0d |  |  |  |
| 437 | 1.15.4.2 | Wewnętrzne wsparcie techniczne w urzędzie |  | 20d | 2022-04-26 | 2022-05-24 | 436SS | 0d |  |  |  |
| 438 | 1.16 | KM: zakończenie stabilizacji platformy | milestone | 0d | 2022-05-24 | 2022-05-24 | 437 | 0d |  |  |  |
| 439 | 1.17 | **Zarządzanie ryzykiem w projekcie** |  | 484.95d | 2020-07-15 | 2022-05-24 |  | 0d |  |  | 193.98h |
| 440 | 1.17.1 | Zarządzanie ryzykiem w projekcie |  | 484.95d | 2020-07-15 | 2022-05-24 | 2SS | 0d |  | Kierownik projektu [5%] | 193.98h |
